# 3GPP_Work Plan

Schedule from MS Project, 2000-01-03 to 2006-06-15, A marks actual dates.

## Calendars

- Standard: Mon-Fri 08:00-12:00, 13:00-17:00; Sat-Sun off.

## Resources

| Resource | Rate |
| --- | --- |
| NP | 2818560300 |
| N1 |  |
| N2 |  |
| N3 |  |
| N4 |  |
| N5 |  |
| TP |  |
| T1 |  |
| T2 |  |
| T3 |  |
| RP |  |
| R1 |  |
| R2 |  |
| R3 |  |
| R4 |  |
| SP |  |
| S1 |  |
| S2 |  |
| S3 |  |
| S4 |  |
| S5 |  |
| PCG |  |
| GP |  |
| No |  |
| CN4 |  |
| ? |  |
| WG G2 |  |
| G2 |  |
| G1 |  |
| G4 |  |
| G3 |  |
| All |  |
| Generic |  |
| MLST |  |
| G5 |  |
| S3, G2 |  |
| WG T2 |  |
| GP,G1 |  |
| G4,G5 |  |
| OMA |  |
| GP-G2 |  |
| Yes |  |
| GP; |  |

## Schedule

| ID | WBS | Task | Duration | Start | Finish | Complete | Remaining | Baseline start | Baseline finish | Baseline duration | Total slack | Constraint | Resources | Work | Actual work | Text6 | Text9 | Text1 | Text4 | Text5 | Text7 | Text8 | Text11 | Text3 | Text2 | Text10 |
| --- | --- | --- | --- | --- | --- | --- | --- | --- | --- | --- | --- | --- | --- | --- | --- | --- | --- | --- | --- | --- | --- | --- | --- | --- | --- | --- |
| 1 | 1 | VERSION 2005 January 13th | 1d | 2000-01-03 | 2000-01-03 |  |  | 2000-01-03 | 2000-01-03 | 1d | 1682d |  |  |  |  | Rel | 2044 |  |  |  |  |  |  |  |  |  |
| 2 | 2 | "CTRL + a" to display all the 3GPP fields | 1d | 2000-01-03 | 2000-01-03 |  |  | 2000-01-03 | 2000-01-03 | 1d | 1682d |  |  |  |  |  | 1462 |  |  |  |  |  |  |  |  |  |
| 3 | 3 | Content of Rel-6 and Rel-7. Not frozen. | 1d | 2000-01-03 | 2000-01-03 |  |  | 2000-01-03 | 2000-01-03 | 1d | 1682d |  |  |  |  | Rel | 2058 |  |  |  |  |  |  |  |  |  |
| 5 | 4 | Rel-6 Evolutions of the transport in the UTRAN | 218d | 2003-03-03 | 2003-12-31 |  |  | 2003-03-03 | 2003-12-31 | 218d | 640d | start no earlier than 2003-03-03 | RP | 1744h |  | NA | Feat | ETRAN | Francois Courau, Alcatel | francois.courau@alcatel.fr | TSG | Cesar | Generic |  |  |  |
| 6 | 8 | **Rel-6 Improvements of Radio Interface** | 1262d? | 2000-08-14 A | 2005-06-15 | 91% | 109.55d? | 2000-08-14 | 2004-09-15 | 1068d | 261d |  | RP | 36040h | 30466.4h | Rel-6 |  | RInImp |  |  | TSG | Cesar |  |  |  |  |
| 7 | 5.1 | Improving Receiver Performance Requirements for the FDD UE | 401d | 2002-03-08 A | 2003-09-19 A | 100% |  | 2002-03-08 | 2003-09-19 | 401d |  | start no earlier than 2002-03-08 | R4 | 3208h | 3208h | Rel-6 | BB | RInImp-UERecPerf | Shimon Moshavi, Intel | shimon.moshavi@INTEL.COM | TSG |  | Active | TS25.101 |  |  |
| 8 | 8.2 | **Base station classification** | 603d | 2000-08-14 A | 2002-12-04 A | 100% |  | 2000-08-14 | 2002-12-04 | 603d |  |  | R4 | 9648h | 9648h | Rel-6 |  | RInImp-BSClass |  |  | TSG |  |  |  |  |  |
| 9 | 8.2.1 | FDD Base station classification | 603d | 2000-08-14 A | 2002-12-04 A | 100% |  | 2000-08-14 | 2002-12-04 | 603d |  | finish no earlier than 2002-12-04 | R4 | 4824h | 4824h | Rel-6 | 1476 | RInImp-BSClass-FDD | A. Toskala, Nokia |  | TSG |  |  | TS25.104, TS25.141 | BaAs |  |
| 10 | 5.3 | UMTS-850 | 266d | 2002-12-06 A | 2003-12-12 A | 100% |  | 2002-12-06 | 2003-12-12 | 266d |  | finish no earlier than 2003-12-15 | R4 | 2128h | 2128h | Rel-6 | BB | RInImp-UMTS850 | Don Zelmer, Cingular | don.zelmer@cingular.com | TSG | MCC_RAN | Active | TS25.101, 25.104, 25.133, 25.141, 25.307, 25.331, TR25.942 |  |  |
| 11 | 5.4 | DS-CDMA introduction in the 800 MHz band | 196d | 2003-03-14 A | 2003-12-12 A | 100% |  | 2003-03-14 | 2003-12-12 | 196d |  | finish no earlier than 2003-12-15 | R4 | 1568h | 1568h | Rel-6 | BB | RInImp-UMTS800 | Takehiro Nakamura, NTT DoCoMo | takehiro@wsp.yrp.nttdocomo.co.jp | TSG | MCC_RAN | Active | TS25.101, 25.104, 25.133, 25.141, 25.307, 25.331 |  |  |
| 12 | 5.5 | UMTS 1.7/2.1 GHz | 261d | 2003-03-14 A | 2004-03-12 A | 100% |  | 2003-03-14 | 2004-03-12 | 261d |  | finish no earlier than 2004-03-15 | R4 | 2088h | 2088h | Rel-6 | BB | RInImp-UMTS1721 | Jussi Numminen, Nokia | jussi.numminen@NOKIA.COM | TSG | MCC RAN | Active | TS25.101, 25.104, 25.133, 25.141, 25.307, 25.331 |  |  |
| 13 | 5.6 | **Improved Receiver Performance Requirements for HSDPA** | 392d? | 2003-12-15 A | 2005-06-15 | 63% | 146.83d? | 2003-12-15 | 2004-09-14 | 197d | 261d |  | R4 | 7304h | 2606.8h | Rel-6 |  | RInImp-HSPerf | Jussi Numminen, Nokia | jussi.numminen@NOKIA.COM | TSG | MCC RAN |  |  |  |  |
| 14 | 5.6.1 | Improved Minimum Performance Requirements for HSDPA UE categories 7 and 8 | 195d? | 2004-09-15 A | 2005-06-15 | 25% | 146.25d? |  |  |  | 261d | finish no earlier than 2005-06-15 | R4 | 1560h | 390h | Rel-6 |  | RInImp-HSPerf-10code | Jussi Numminen, Nokia | jussi.numminen@nokia.com | TSG | MCC_RAN |  | TS25.101 |  |  |
| 15 | 5.6.2 | Performance Requirements of Receive Diversity for HSDPA | 326d | 2003-12-15 A | 2005-03-15 | 85% | 48.9d | 2003-12-15 | 2004-09-14 | 197d | 327d | finish no earlier than 2005-03-15 | R4 | 2608h | 2216.8h | Rel-6 |  | RInImp-HSPerf-RxDiv | Takehiro Nakamura (NTT DoCoMo) | takehiro@wsp.yrp.nttdocomo.co.jp | TSG | MCC RAN |  | TS25.101 |  |  |
| 16 | 6 | **Rel-6 RAN Feasibility Studies** | 1196d? | 2000-08-14 A | 2005-03-15 | 89% | 137.25d? | 2000-08-14 | 2005-03-15 | 1197d | 327d |  | RP | 43048h | 32300.8h | Rel-6 |  |  |  |  |  | Cesar |  |  |  |  |
| 17 | 6.1 | FS of the improved access to UE measurement data for CRNC to support TDD RRM | 270d? | 2002-12-06 A | 2003-12-18 A | 100% |  | 2002-12-06 | 2003-12-18 | 270d? |  | finish no earlier than 2003-09-19 | R3 | 2160h | 2160h | Rel-6 |  | RANimp-RRMopt-FSUEMsD | Jim Miller, Interdigital | jim.miller@interdigital.com | TSG |  |  |  |  | SP-24 |
| 18 | 6.2 | FS on Radio link performance enhancements | 1067d | 2000-08-14 A | 2004-09-14 A | 100% |  | 2000-08-14 | 2004-06-15 | 1002d |  | finish no earlier than 2004-09-14 | R1 | 8536h | 8536h | Rel-6 | SI | RInImp-Rlperf | Antti Toskala, Nokia Networks | antti.toskala@nokia.com | TSG | MCC_RAN | Active | TR25.899 |  |  |
| 19 | 6.3 | FS on Improvement of inter-frequency and inter-system measurements for 1.28 Mcps TDD | 461d | 2001-12-14 A | 2003-09-19 A | 100% |  | 2001-12-14 | 2003-09-19 | 461d |  | start no earlier than 2001-12-14 | R1 | 3688h | 3688h | Rel-6 | SI | RInImp-IfIsMLCR | Li Xiao Qiang, SAMSUNG | xqli@samsung.co.kr | TSG |  | Active | TR25.888 |  |  |
| 20 | 6.4 | FS for the analysis of OFDM for UTRAN enhancement | 526d | 2002-06-10 A | 2004-06-14 A | 100% |  | 2002-06-10 | 2004-06-14 | 526d |  | start no earlier than 2002-06-10 | R1 | 4208h | 4208h | Rel-6 | SI | RInImp-FSOFDM | Sarah Boumendil, Nortel | boumendi@nortelnetworks.com | TSG | MCC_RAN | Active | TR25.892 |  |  |
| 21 | 6.5 | FS on Uplink Enhancements for Dedicated Transport Channels | 396d | 2002-09-06 A | 2004-03-12 A | 100% |  | 2002-09-06 | 2004-03-12 | 396d |  | finish no earlier than 2004-03-12 | R1 | 3168h | 3168h | Rel-6 | SI | RInImp-FSUpDTrCh | Karri Ranta-aho, Nokia | Karri.Ranta-aho@nokia.com | TSG | MCC_RAN | Active | TR25.896 |  |  |
| 22 | 6.6 | FS on Analysis on Higher Chip Rates for UTRA TDD evolutions | 528d | 2002-09-06 A | 2004-09-14 A | 100% |  | 2002-09-06 | 2004-06-14 | 462d |  | finish no earlier than 2004-09-14 | R1 | 4224h | 4224h | Rel-6 | SI | RInImp-FSVHCRTDD | Tim Wilkinson, IPWireless | mbeale@ipwireless.com | TSG | MCC_RAN | Active | TR25.895 |  |  |
| 23 | 6.7 | FS on Low Output Powers for general purpose FDD BSs | 128d | 2003-06-13 A | 2004-03-12 A | 100% |  | 2003-06-13 | 2004-03-12 | 128d |  | finish no earlier than 2004-03-12 | R3 | 1024h | 1024h | Rel-6 | SI | RInImp-FSLoPw | Ana Burgos, Telefonica | burgos_a@tsm.es | TSG | MCC_RAN | Active | TR25.807 |  |  |
| 24 | 6.8 | FS on Uplink enhancements for UTRA TDD | 462d | 2003-06-06 A | 2005-03-15 | 70% | 138.6d | 2003-06-06 | 2004-09-14 | 333d | 327d | finish no earlier than 2005-03-15 | R1 | 3696h | 2587.2h | Rel-6 | SI | RInImp-FSUpEnhTDD | Marian Rudolf, Interdigital | Marian.Rudolf@InterDigital.com | TSG | MCC_RAN | Active | TR25.804 |  |  |
| 25 | 8.8 | FS on UE antenna efficiency test methods performance requirements (2) | 131d | 2002-03-08 A | 2002-09-06 A | 100% |  | 2002-03-08 | 2002-09-06 | 131d |  | finish no earlier than 2002-09-06 | R4 | 1048h | 1048h | Rel-6 |  | RInImp-UEAnTM2 | Alf Ahlström, Allgon |  | TSG |  |  |  |  |  |
| 26 | 9.4 | Deleted - FS on the evolution of the UTRAN architecture | 592d | 2002-09-09 A | 2004-12-15 | 35% | 384.8d | 2002-09-09 | 2005-03-15 | 657d | 391d | finish no earlier than 2004-12-15 | R3 | 4736h | 1657.6h | Rel-6 |  | RANimp-FSEvo | Woonhee Hwang, Nokia | Antti.Toskala@nokia.com | TSG | MCC_RAN |  |  |  |  |

Notes:
- 5: Generic feature
- 6: This is a generic feature without particular end date
- 14: Approved at RP#25 as RP-040375
- 18: Study finished at RP#25
- 22: Study finished at RP#25
- 25: The RInImp-UEAnTM FS was re-opened at TSG RAN#15 upon request from WG4
- 26: Study Closed, work will continue within the FS on evolved UTRA and UTRAN

| ID | WBS | Task | Duration | Start | Finish | Complete | Remaining | Baseline start | Baseline finish | Baseline duration | Total slack | Constraint | Resources | Work | Actual work | Text1 | Text4 | Text6 | Text7 | Text8 | Text9 | Text11 | Text3 | Text5 | Text2 | Text12 | Text10 |
| --- | --- | --- | --- | --- | --- | --- | --- | --- | --- | --- | --- | --- | --- | --- | --- | --- | --- | --- | --- | --- | --- | --- | --- | --- | --- | --- | --- |
| 27 | 7 | **FDD Enhanced Uplink** | 327d | 2004-03-15 A | 2005-06-15 | 69% | 101.36d | 2004-03-15 | 2005-06-15 | 327d | 261d |  | RP | 13072h | 7214.8h | EDCH | Joakim Bergström (Ericsson) | Rel-6 | TSG | Cesar | Feat | Active |  |  |  |  |  |
| 28 | 7.1 | FDD Enhanced Uplink - Stage 2 | 197d | 2004-03-15 A | 2004-12-14 A | 100% |  | 2004-03-15 | 2004-03-15 | 1d |  | finish no earlier than 2004-12-14 | R2 | 1576h | 1576h | EDCH-Stage2 |  | Rel-6 | TSG |  |  |  | TS 25.309 |  |  |  |  |
| 29 | 7.2 | FDD Enhanced Uplink - Physical Layer | 261d | 2004-03-15 A | 2005-03-15 | 85% | 39.15d | 2004-03-15 | 2004-12-15 | 197d | 327d | finish no earlier than 2005-03-15 | R1 | 2088h | 1774.8h | EDCH-Phys | Karri Ranta-aho (Nokia) | Rel-6 | TSG | MCC RAN | BB | Active | TS25.211, 25.212, 25.213, 25.214, 25.215 |  |  |  |  |
| 30 | 7.3 | FDD Enhanced Uplink - Layer 2 and 3 Protocol Aspects | 261d | 2004-03-15 A | 2005-03-15 | 80% | 52.2d | 2004-03-15 | 2004-12-15 | 197d | 327d | finish no earlier than 2005-03-15 | R2 | 2088h | 1670.4h | EDCH-L23 | Joakim Bergström (Ericsson) | Rel-6 | TSG | MCC RAN | BB | Active | TS25.301, 25.302, 25.306, 25.321, 25.331 |  |  |  |  |
| 31 | 7.4 | FDD Enhanced Uplink - UTRAN Iub/Iur Protocol Aspects | 261d | 2004-03-15 A | 2005-03-15 | 80% | 52.2d | 2004-03-15 | 2004-12-15 | 197d | 327d | finish no earlier than 2005-03-15 | R3 | 2088h | 1670.4h | EDCH-IurIub | Saso Stojanovski (Nortel) | Rel-6 | TSG | MCC RAN | BB | Active | TS25.401, 25.420, 25.423, 25.430, 25.433 |  |  |  |  |
| 32 | 7.5 | FDD Enhanced Uplink - RF Radio Transmission/ Reception, System Performance Requirements and Conformance Testing | 327d | 2004-03-15 A | 2005-06-15 | 20% | 261.6d | 2004-03-15 | 2005-06-15 | 327d | 261d | finish no earlier than 2005-06-15 | R4 | 2616h | 523.2h | EDCH-RF | Thomas Unshelm (Ericsson) | Rel-6 | TSG | MCC RAN | BB | Active | TS25.101, 25.104, 25.133, 25.141 | thomas.unshelm@ERICSSON.COM |  |  |  |
| 33 | 9 | **Rel-6 RAN improvements** | 776d? | 2002-03-25 A | 2005-03-15 | 77% | 177.32d? | 2002-09-09 | 2004-12-15 | 592d? | 327d |  | RP | 31872h | 21099.1h | RANimp |  | Rel-6 | TSG | Cesar |  |  |  |  |  |  |  |
| 34 | 9.2 | **RAB support enhancement** | 776d? | 2002-03-25 A | 2005-03-15 | 57% | 333.54d? | 2003-03-14 | 2004-12-15 | 458d? | 327d |  | R2 | 12920h | 7366.69h | RANimp-RABSE | Juha Mikola, Nokia | Rel-6 | TSG | MCC RAN | 624 |  | TR 25.862 | juha.mikola@nokia.com | BaAS |  |  |
| 35 | 8.1.1 | Iu enhancements for IMS support in RAN | 320d? | 2003-03-14 A | 2004-06-03 | 25% | 240d? | 2003-03-14 | 2004-12-15 | 458d? | 529d | start no earlier than 2003-03-14 | R3 | 2560h | 640h | RANimp-RABSE-IuEnhIMS | Phillipe Godin, Nortel | Rel-6 | TSG | MCC RAN |  |  |  | Philippe.Godin@nortelnetworks.com |  |  |  |
| 36 | 8.1.2 | Optimisation of downlink channelisation code utilisation | 262d | 2004-03-12 A | 2005-03-15 | 90% | 26.2d | 2004-03-12 | 2004-12-15 | 198d | 327d | finish no earlier than 2005-03-15 | R1 | 2096h | 1886.4h | RANimp-RABSE-CodeOptFDD | Sarah Boumendil (Nortel Networks) | Rel-6 | TSG | MCC RAN | WT | Active |  | boumendi@nortelnetworks.com |  |  |  |
| 37 | 8.1.3 | Optimisation of channelisation code utilisation for 3.84 Mcps TDD | 261d | 2004-03-15 A | 2005-03-15 | 90% | 26.1d | 2004-03-15 | 2004-12-15 | 197d | 327d | finish no earlier than 2005-03-15 | R1 | 2088h | 1879.2h | RANimp-RABSE-CodOptTDD | Nicholas Anderson (IPWireless) | Rel-6 | TSG | MCC RAN | WT | Active |  |  |  |  |  |
| 38 | 8.1.4 | HS-DPCCH ACK/NACK Enhancement | 65d? | 2004-09-15 A | 2004-12-15 A | 100% |  |  |  |  |  | finish no earlier than 2004-12-15 | R1 | 520h | 520h | RANimp-RABSE-ACKNACK | Jussi Kähtävä, Nokia | Rel-6 | TSG | MCC_RAN |  |  | TS25.212, TS25.214, TS24.331, TS25.433 |  |  |  |  |
| 39 | 8.1.5 | Deleted - Improvement of RRM across RNS and RNS/BSS | 445d? | 2002-03-25 A | 2003-12-05 | 35% | 289.25d? |  |  |  | 658d | finish no earlier than 2003-12-05 | R3 | 3560h | 1246h | RANimp-RRM1 | Antti Toskala, Nokia | Rel-6 |  |  |  |  |  |  |  | RP-23 |  |
| 40 | 9.1 | Beamforming Enhancements | 66d | 2003-09-19 A | 2003-12-19 A | 100% |  | 2003-09-19 | 2003-12-19 | 66d |  | finish no earlier than 2004-03-12 | R1 | 528h | 528h | RANimp-BFE | Jussi Kähtävä, Nokia | Rel-6 | TSG | MCC_RAN |  |  | TS24.215, 25.423, 25.425, 25.433, 25.435 | jussi.kahtava@nokia.com |  |  |  |
| 41 | 8.3 | **Rel6 RRM optimization for Iur and Iub** | 126d | 2003-09-19 A | 2004-03-12 A | 100% |  | 2003-09-19 | 2004-03-12 | 126d |  |  | R3 | 2016h | 2016h | RANimp-RRMopt | Gert-Jan van Lieshout, Ericsson | Rel-6 | TSG | MCC_RAN |  |  |  | Gert-Jan.van.Lieshout@eln.ericsson.se | BaAS |  |  |
| 42 | 8.3.1 | Improved access to UE measurement data for CRNC to support TDD RRM | 126d | 2003-09-19 A | 2004-03-12 A | 100% |  | 2003-09-19 | 2004-03-12 | 126d |  | finish no earlier than 2004-03-15 | R3 | 1008h | 1008h | RANimp-RRMopt-UEMsD | Jim Miller, Interdigital | Rel-6 | TSG | MCC RAN | WT | Active | TS25.423 | jim.miller@interdigital.com |  | RP-22 |  |
| 43 | 8.4 | **Remote Control of Electrical Tilting Antennas** | 395d? | 2003-03-14 A | 2004-09-16 | 99% | 0d? | 2003-03-14 | 2004-09-16 | 395d? | 0d |  | R3 | 7464h | 5428.47h | RANimp-TiltAnt | Andreas Hauser, Vodafone | Rel-6 | TSG | MCC_RAN |  |  |  | Andreas.Hauser@vodafone.com |  |  |  |
| 44 | 8.4.1 | Tilting Antenna - RAN aspects | 393d? | 2003-03-14 A | 2004-09-14 A | 100% |  | 2003-03-14 | 2004-09-15 | 394d? |  | finish no earlier than 2004-09-14 | R3 | 3144h | 3144h | RANimp-TiltAnt | Andreas Hauser, Vodafone | Rel-6 | TSG | MCC_RAN |  |  | TS25.460, 25.461, 25.462, 25.463 | Andreas.Hauser@vodafone.com |  |  |  |
| 45 | 8.4.2 | OAM&P impacts | 145d | 2004-02-27 A | 2004-09-16 A | 100% |  | 2004-02-27 | 2004-09-16 | 145d |  | finish no earlier than 2004-09-16 | S5 | 1160h | 1160h | RANimp-TiltAnt-OAM | John MUDGE, Vodafone | Rel-6 | WG | Adrian |  |  | 32.804, 32.xyz | john.mudge@vodafone.co.uk |  |  | SP-24 |
| 46 | 8.5 | Network Assisted Cell Change (NACC) from UTRAN to GERAN - network-side aspects | 462d? | 2002-09-09 A | 2004-06-15 A | 100% |  | 2002-09-09 | 2004-06-15 | 462d? |  | finish no earlier than 2004-06-15 | R3 | 3696h | 3696h | RANimp-NACC | Brendan McWilliams, Vodafone | Rel-6 | TSG | MCC_RAN |  |  |  | Brendan.McWilliams@gb.vodafone.co.uk |  |  |  |
| 47 | 12 | **Location Services enhancements 2** | 1124d? | 2000-08-28 A | 2004-12-16 | 79% | 233.12d? | 2000-08-28 | 2004-10-29 | 1090d? | 389d |  | S2 | 83792h | 60255.7h | LCS2 |  | Rel-6 | TSG | Sang-Ui |  |  | 23.271 |  |  |  |  |
| 48 | 12.1 | **Improvement on Le interface** | 653d? | 2002-06-17 A | 2004-12-15 | 76% | 158.47d? | 2002-06-17 | 2004-10-29 | 620d? | 390d |  | S2 | 9872h | 7476.21h |  |  | Rel-6 | TSG |  |  |  |  |  |  |  |  |
| 49 | 9.1.1 | Stage 2 | 331d? | 2002-06-17 A | 2003-09-22 A | 100% |  | 2002-06-17 | 2003-09-22 | 331d? |  | start no earlier than 2002-06-17 | S2 | 2648h | 2648h |  |  | Rel-6 |  |  |  |  |  |  |  |  |  |
| 50 | 9.1.2 | Stage 3 - impacts MLP (Mobile Location Protocol) | 250d? | 2004-01-01 A | 2004-12-15 | 44% | 141d? | 2003-07-10 | 2004-10-29 | 342d? | 390d | finish no earlier than 2004-12-15 | OMA | 2000h | 872h |  |  | Rel-6 |  |  |  |  |  | OMA-LIAISON@mail.openmobilealliance.org |  |  |  |

Notes:
- 33: Generic feature
- 34: This is a building block without particular end date
- 35: Closed RAN#24 due to the lack of progress
- 37: WIDS modified in RP#26, RP-040551
- 38: Approved at RP#25 as RP-040390
- 39: abandoned RP-23
- 44: Finished at RP#25
- 45: az: WID approved at SA5#37 (02/2004)
- 50: Updated according to SP-040232

| ID | WBS | Task | Duration | Start | Finish | Complete | Remaining | Baseline start | Baseline finish | Baseline duration | Total slack | Constraint | Resources | Work | Actual work | Text6 | Text7 | Text5 | Text1 | Text8 | Text4 | Text9 | Text12 | Text2 |
| --- | --- | --- | --- | --- | --- | --- | --- | --- | --- | --- | --- | --- | --- | --- | --- | --- | --- | --- | --- | --- | --- | --- | --- | --- |
| 51 | 12.2 | **Enhanced support for anonymity and user privacy** | 638d? | 2002-07-08 A | 2004-12-15 | 72% | 178.13d? | 2002-07-08 | 2004-10-29 | 605d? | 390d |  | S2 | 9144h | 6590.92h | Rel-6 | TSG |  |  |  |  |  |  |  |
| 52 | 9.2.1 | Stage 2 | 255d? | 2002-07-08 A | 2003-06-27 A | 100% |  | 2002-07-08 | 2003-06-27 | 255d? |  | finish no earlier than 2003-06-27 | S2 | 2040h | 2040h | Rel-6 |  |  |  |  |  |  |  |  |
| 53 | 9.2.2 | Stage 3 - impacts MLP and RLP | 250d? | 2004-01-01 A | 2004-12-15 | 44% | 141d? | 2003-07-10 | 2004-10-29 | 342d? | 390d | finish no earlier than 2004-12-15 | OMA | 2000h | 872h | Rel-6 |  | OMA-LIAISON@mail.openmobilealliance.org |  |  |  |  |  |  |
| 54 | 12.3 | **Enhanced inter-GMLC interface** | 648d? | 2002-06-24 A | 2004-12-15 | 91% | 60.79d? | 2002-06-24 | 2004-10-29 | 615d? | 390d |  | S2 | 9704h | 8793.71h | Rel-6 | TSG |  |  |  |  |  |  |  |
| 55 | 9.3.1 | Stage 2 | 315d? | 2002-06-24 A | 2003-09-05 A | 100% |  | 2002-06-24 | 2003-09-05 | 315d? |  | finish no earlier than 2003-09-05 | S2 | 2520h | 2520h | Rel-6 |  |  |  |  |  |  |  |  |
| 56 | 9.3.2 | Stage 3 - definition of RLP and PCP | 250d? | 2004-01-01 A | 2004-12-15 | 79% | 53d? | 2002-09-02 | 2004-10-29 | 565d? | 390d | finish no earlier than 2004-12-15 | OMA | 2000h | 1576h | Rel-6 |  | OMA-LIAISON@mail.openmobilealliance.org |  |  |  |  |  |  |
| 57 | 12.4 | **Location Services support for IMS public identities** | 473d? | 2003-02-24 A | 2004-12-15 | 89% | 51.16d? | 2002-09-02 | 2004-10-29 | 565d? | 390d |  | S2 | 7704h | 5022.55h | Rel-6 | TSG |  |  |  |  |  |  |  |
| 58 | 9.4.1 | Stage 2 | 240d? | 2003-02-24 A | 2004-01-23 A | 100% |  | 2003-02-24 | 2004-01-23 | 240d? |  | finish no earlier than 2004-01-23 | S2 | 1920h | 1920h | Rel-6 |  |  |  |  |  |  |  |  |
| 59 | 9.4.2 | Stage 3 - impacts MLP, RLP and PCP | 250d? | 2004-01-01 A | 2004-12-15 | 79% | 53d? | 2002-09-02 | 2004-10-29 | 565d? | 390d | finish no earlier than 2004-12-15 | OMA | 2000h | 1576h | Rel-6 |  | OMA-LIAISON@mail.openmobilealliance.org |  |  |  |  |  |  |
| 60 | 12.5 | **New area event for location service triggering reports** | 663d? | 2002-06-03 A | 2004-12-15 | 80% | 132.51d? | 2002-06-03 | 2004-10-29 | 630d? | 390d |  | S2 | 11416h | 7122.43h | Rel-6 | TSG |  |  |  |  |  |  |  |
| 61 | 9.5.1 | Stage 2 | 280d? | 2002-06-03 A | 2003-06-27 A | 100% |  | 2002-06-03 | 2003-06-27 | 280d? |  | finish no earlier than 2003-06-27 | S2 | 2240h | 2240h | Rel-6 |  |  |  |  |  |  |  |  |
| 62 | 9.5.2 | Stage 3 for UE-CN signalling | 234d? | 2003-10-09 A | 2004-08-31 | 95% | 11.7d? | 2003-10-09 | 2004-08-31 | 234d? | 466d | start no earlier than 2003-10-09 | N4 | 1872h | 1778.4h | Rel-6 |  |  |  |  |  |  |  |  |
| 63 | 9.5.3 | Stage 3 - impacts MLP, RLP and PCP | 250d? | 2004-01-01 A | 2004-12-15 | 44% | 141d? | 2003-07-14 | 2004-10-29 | 340d? | 390d | finish no earlier than 2004-12-15 | OMA | 2000h | 872h | Rel-6 |  | OMA-LIAISON@mail.openmobilealliance.org |  |  |  |  |  |  |
| 64 | 12.7 | **UE positioning** | 1057d? | 2000-08-28 A | 2004-09-14 | 72% | 295.72d? | 2000-08-28 | 2004-09-15 | 1058d? | 456d |  | RP | 24920h | 15751h | Rel-6 | TSG |  | LCS2-UEpos | MCC_RAN |  |  |  |  |
| 65 | 12.8 | Open SMLC-SRNC Interface within the UTRAN to support UTRAN Rel4 positioning methods | 700d? | 2001-01-15 A | 2003-09-19 A | 100% |  | 2001-01-15 | 2003-09-19 | 700d? |  | finish no earlier than 2003-09-19 | R2 | 5600h | 5600h | Rel-6 | TSG | Meik.Kottkamp@siemens.com | LCS-Rel4Pos |  | Meik Kottkamp, Siemens | 2475 |  |  |
| 66 | 9.6.2 | A-GPS minimum performance specification | 333d? | 2003-06-06 A | 2004-09-14 A | 100% |  | 2003-06-06 | 2004-09-15 | 334d? |  | finish no earlier than 2004-09-14 | R4 | 2664h | 2664h | Rel-6 | TSG | donglin.shen@attws.com | LCS-UEPos-AGPSPerf | MCC_RAN | Donglin Shen, AT&T Wireless Services |  |  |  |
| 67 | 12.7.2 | FS on Enhancements to OTDOA Positioning using advanced blanking methods | 320d | 2002-07-01 A | 2003-09-19 A | 100% |  | 2002-07-01 | 2003-09-19 | 320d |  | finish no earlier than 2003-09-19 | R2 | 2560h | 2560h | Rel-6 | TSG | david.bartlett@cursor-system.com | LCS2-UEpos-FSBlank |  | David Bartlett, Cambridge Positioning Systems |  |  |  |
| 68 | 9.6.4 | Deleted - UE positioning enhancements - other methods | 805d? | 2000-08-28 A | 2003-09-26 | 25% | 603.75d? |  |  |  | 708d | finish no earlier than 2003-09-26 | R2 | 6440h | 1610h | Rel-6 |  |  | LCS2-UEpos-enh |  | Meik Kottkamp, Siemens |  | RP-24 |  |
| 69 | 9.7 | LCS charging | 455d? | 2003-03-21 A | 2004-12-16 A | 100% |  |  |  |  |  | start no earlier than 2003-03-21 | S5 | 3640h | 3640h | Rel-6 | TSG |  | LCS2-CH |  |  |  |  |  |
| 70 | 14 | **Rel-6 Security enhancements** | 1018d? | 2001-01-03 A | 2004-11-26 | 75% | 250.03d? | 2001-01-03 | 2004-06-18 | 903d? | 403d |  | S3 | 28824h | 20642.1h | Rel-6 | TSG | Peter.Howard@vodafone.com | SEC1 | Maurice | Peter Howard, Vodafone |  |  |  |
| 71 | 14.1 | **Enhanced HE control of security (including positive authentication reporting)** | 712d | 2001-01-03 A | 2003-09-25 | 47% | 378d | 2001-01-03 | 2003-09-25 | 712d | 709d |  | S3 | 14064h | 7882.4h | Rel-6 |  | Peter.Howard@vodafone.com |  |  | Peter Howard, Vodafone | 2026 |  |  |
| 72 | 14.1.1 | Stage 2 | 378d | 2001-01-03 | 2002-06-14 |  |  | 2001-01-03 | 2002-06-14 | 378d | 1043d | finish no earlier than 2002-06-14 | S3 | 3024h |  | Rel-6 |  |  |  |  |  | 2027 |  |  |
| 73 | 14.1.3 | **Network domain security** | 334d | 2002-06-17 A | 2003-09-25 | 99% | 0d | 2002-06-17 | 2003-09-25 | 334d | 0d |  | S3 | 5344h | 5210.4h | Rel-6 | TSG | Geir-myrdahl.koien@telenor.com | SEC1-NDS |  | Geir M. Køien, Telenor |  |  | Sec |
| 74 | 14.1.3.1 | IP network layer security (NDS/IP) | 334d | 2002-06-17 A | 2003-09-25 A | 100% |  | 2002-06-17 | 2003-09-25 | 334d |  | finish no earlier than 2003-09-25 | S3 | 2672h | 2672h | Rel-6 | WG |  | SEC1-NDS-IP |  |  |  |  |  |
| 75 | 10.2 | Network Domain Security; Authentication Framework (NDS/AF) | 521d? | 2002-02-15 A | 2004-02-13 A | 100% |  | 2002-02-15 | 2004-02-13 | 521d? |  | finish no earlier than 2004-02-13 | S3 | 4168h | 4168h | Rel-6 | TSG | tommi.viitanen@nokia.com | SEC1-NDS-AF |  | Tommi Viitanen, Nokia |  |  |  |
| 76 | 10.3 | Key Management of group keys for Voice Group Call Services | 306d | 2003-09-26 A | 2004-11-26 A | 100% |  | 2003-09-26 | 2004-06-18 | 191d |  | finish no earlier than 2004-11-26 | S3 | 2448h | 2448h | Rel-6 | TSG | benno.tietz@vodafone.com | SECGKYV | Maurice | Benno Tietz, Vodafone D2 |  |  |  |

Notes:
- 53: Updated according to SP-040232
- 56: Updated according to SP-040232
- 59: Updated according to SP-040232
- 62: 31/10/2003 work has started. Current stage 3 fullfills the requirements of stage 2. ......
- 63: Updated according to SP-040232
- 65: Text3: TS25.305, 25.401, 25.450, 25.452, 25.453
- 66: Finished at RP#25 / Text3: TS25.171
- 68: This is a building block without particular end date
- 69: SA#26 12/2004 completed / Text3: 32.271
- 70: Added BB UE authentication and rapporteur added.
- 71: Added by SP-000575 without any dates. 18/10/00: Change of WI title, added hyperlink rapporteur new end date 03/01. New end date and correct Release to be decided S3#18
- 72: New end date and correct Release to be decided S3#18
- 73: WID approved for Rel-6 at SA#17. Completed 2004-12
- 74: Should be complete after SA3#27. Completed 2004-12 / Text3: TS 33.210
- 75: WID approved SA#19. Work started after FS approved SA#18
- 76: Approved TSG#21. Completed 2004-12 / Text3: 42.068, 43.068, 44.068, 42.069, 43.069, 44.069, 31.102, 24.008, 48.008, 42.009, 43.020

| ID | WBS | Task | Duration | Start | Finish | Complete | Remaining | Baseline start | Baseline finish | Baseline duration | Total slack | Constraint | Resources | Work | Actual work | Text1 | Text3 | Text6 | Text7 | Text8 | Text4 | Text5 | Text2 | Text9 | Text12 |
| --- | --- | --- | --- | --- | --- | --- | --- | --- | --- | --- | --- | --- | --- | --- | --- | --- | --- | --- | --- | --- | --- | --- | --- | --- | --- |
| 77 | 16 | **IMS Phase 2** | 1434d? | 2000-01-03 A | 2005-06-30 | 89% | 152.99d? | 2000-08-28 | 2004-11-30 | 1112d? | 249d |  | S1 | 119408h | 100220h | IMS2 | 23.228 | Rel-6 | TSG | Sang-Ui |  |  |  |  |  |
| 78 | 11.1 | Enhancements to the Cx and Sh interfaces | 323d? | 2003-06-06 A | 2004-08-31 | 95% | 16.15d? | 2003-06-06 | 2004-08-31 | 323d? | 466d | finish no earlier than 2004-08-31 | N4 | 2584h | 2454.8h | IMS2-CCR |  | Rel-6 | WG |  |  |  |  |  |  |
| 79 | 16.12 | **IMS Group Management** | 715d? | 2002-03-14 A | 2004-12-08 | 88% | 85.31d? | 2002-03-14 | 2004-09-08 | 650d? | 395d |  | S1 | 12680h | 11167.1h | IMSGM |  | Rel-6 | TSG |  | Juha Kalliokulju (Nokia) | juha.kalliokulju@nokia.com |  |  |  |
| 80 | 16.12.1 | Stage 1 - TS on IMS group management | 193d | 2002-03-14 A | 2002-12-09 A | 100% |  | 2002-03-14 | 2002-12-09 | 193d |  | finish no earlier than 2002-12-09 | S1 | 1544h | 1544h |  |  | Rel-6 | TSG |  | Juha Kalliokulju (Nokia) | juha.kalliokulju@nokia.com |  |  |  |
| 81 | 11.2.2 | Stage 2 | 158d? | 2003-05-26 A | 2003-12-31 A | 100% |  | 2003-05-26 | 2003-12-31 | 158d? |  | finish no earlier than 2003-12-31 | S2 | 1264h | 1264h |  |  | Rel-6 |  |  |  |  |  |  |  |
| 82 | 11.2.3 | Stage 3 for IMS Group management (e.g. chat) | 519d? | 2002-12-13 A | 2004-12-08 | 80% | 103.8d? | 2002-12-13 | 2004-09-08 | 454d? | 395d | finish no earlier than 2004-12-08 | N1 | 4152h | 3321.6h |  |  | Rel-6 |  |  | Keith Drage, Lucent | drage@lucent.com |  |  |  |
| 83 | 11.3 | **IMS Conferencing** | 548d? | 2002-11-04 A | 2004-12-08 | 94% | 34.6d? | 2002-11-04 | 2004-09-08 | 483d? | 395d |  | N1 | 10960h | 10268h |  |  | Rel-6 |  |  |  |  |  |  |  |
| 84 | 11.3.1 | Stage 2 | 303d? | 2002-11-04 A | 2003-12-31 A | 100% |  | 2002-11-04 | 2003-12-31 | 303d? |  | finish no earlier than 2003-12-31 | S2 | 2424h | 2424h |  |  | Rel-6 |  |  |  |  |  |  |  |
| 85 | 11.3.2 | Stage 3 | 519d? | 2002-12-13 A | 2004-12-08 | 90% | 51.9d? | 2002-12-13 | 2004-09-08 | 454d? | 395d | finish no earlier than 2004-12-08 | N1 | 4152h | 3736.8h |  |  | Rel-6 |  |  | Keith Drage, Lucent | drage@lucent.com |  |  |  |
| 86 | 16.11 | **IMS Messaging** | 861d? | 2002-03-14 A | 2005-06-30 | 75% | 216.33d? | 2002-03-14 | 2004-09-08 | 650d? | 249d |  | S1 | 21816h | 16334.5h | IMSM |  | Rel-6 | TSG |  | Juha Kalliokulju (Nokia) | juha.kalliokulju@nokia.com |  |  |  |
| 87 | 16.11.1 | TR on support of messaging in the IMS | 193d | 2002-03-14 A | 2002-12-09 A | 100% |  | 2002-03-14 | 2002-12-09 | 193d |  | finish no earlier than 2002-12-09 | S1 | 1544h | 1544h | IMSM-TR |  | Rel-6 | TSG |  | Juha Kalliokulju (Nokia) | juha.kalliokulju@nokia.com |  |  |  |
| 88 | 11.4.2 | Stage 1 22.340 | 23d? | 2002-11-11 A | 2002-12-11 A | 100% |  | 2002-11-11 | 2002-12-11 | 23d? |  | finish no earlier than 2002-12-11 | S1 | 184h | 184h | IMSM-TS | 22.340 | Rel-6 | TSG |  | Juha Kalliokulju (Nokia) | juha.kalliokulju@nokia.com |  |  |  |
| 89 | 11.4.3 | CRs to 22.140 & 22.228 | 263d? | 2002-03-14 A | 2003-03-17 A | 100% |  | 2002-03-14 | 2003-03-17 | 263d? |  | finish no earlier than 2003-03-17 | S1 | 2104h | 2104h | IMSM-CR | 22.140,22.228 | Rel-6 | TSG |  | Juha Kalliokulju (Nokia) | juha.kalliokulju@nokia.com |  |  |  |
| 90 | 16.11.3 | Stage 2 | 477d | 2002-11-04 A | 2004-08-31 A | 100% |  | 2002-11-04 | 2004-08-31 | 477d |  | finish no earlier than 2004-08-31 | S2 | 3816h | 3816h |  |  | Rel-6 |  |  |  |  |  |  |  |
| 91 | 11.4.5 | Stage 3 for IMS Messaging | 519d? | 2002-12-13 A | 2004-12-08 | 85% | 77.85d? | 2002-12-13 | 2004-09-08 | 454d? | 395d | finish no earlier than 2004-12-08 | N1 | 4152h | 3529.2h |  |  | Rel-6 |  |  | Keith Drage, Lucent | drage@lucent.com |  |  |  |
| 92 | 11.4.6 | SIP/SIMPLE Instant messaging | 391d? | 2004-01-01 | 2005-06-30 |  |  | 2004-01-01 | 2004-06-30 | 130d? | 249d | finish no earlier than 2005-06-30 | OMA | 3128h |  |  |  | Rel-6 | n/a |  |  | OMA-LIAISON@mail.openmobilealliance.org |  |  |  |
| 93 | 11.5 | **Additional SIP Capabilities support not covered by Rel-5** | 478d? | 2002-11-11 A | 2004-09-08 | 97% | 13.75d? | 2002-11-11 | 2004-09-08 | 478d? | 460d |  | N1 | 10136h | 9844.38h |  |  | Rel-6 |  |  |  |  |  |  |  |
| 94 | 11.5.1 | Stage 2 for add SIP cap (e.g. forking) | 335d? | 2002-11-11 A | 2004-02-20 A | 100% |  | 2002-11-11 | 2004-02-20 | 335d? |  | finish no earlier than 2004-02-20 | S2 | 2680h | 2680h |  |  | Rel-6 |  |  |  |  |  |  |  |
| 95 | 11.5.2 | Stage 3 for Additional SIP Capabilities | 454d? | 2002-12-13 A | 2004-09-08 | 95% | 22.7d? | 2002-12-13 | 2004-09-08 | 454d? | 460d | finish no earlier than 2004-09-08 | N1 | 3632h | 3450.4h |  |  | Rel-6 |  |  | Keith Drage, Lucent | drage@lucent.com |  |  |  |
| 96 | 11.6 | Review additional SIP Capabilities against IMS | 454d? | 2002-12-13 A | 2004-09-08 A | 100% |  | 2002-12-13 | 2004-03-12 | 326d? |  | finish no earlier than 2004-09-08 | N1 | 3632h | 3632h |  |  | Rel-6 |  |  | Keith Drage, Lucent | drage@lucent.com |  |  |  |
| 97 | 16.5 | **Interworking between IMS and IP networks** | 1118d? | 2000-08-28 A | 2004-12-08 | 88% | 131.76d? | 2000-08-28 | 2004-09-10 | 1055d? | 395d |  | N3 | 31712h | 22204.8h | IMS-CCR-IWIP | 23.821, 29.061, 29.162 | Rel-6 | TSG |  | Nigel Holland, BT | nigel.holland@bt.com | BaAS | 2048 |  |
| 98 | 16.5.1 | Interworking for 3GPP_SIP and IETF_SIP | 730d | 2000-08-28 A | 2003-06-13 A | 100% |  | 2000-08-28 | 2003-06-13 | 730d |  | finish no earlier than 2003-06-13 | N3 | 5840h | 5840h |  | New TR 29.962 | Rel-6 |  |  | Thomas Belling, Siemens |  |  |  |  |
| 99 | 16.5.2 | Interworking for IPv6 to IPv4 | 1118d | 2000-08-28 A | 2004-12-08 | 70% | 335.4d | 2000-08-28 | 2004-09-10 | 1055d | 395d | finish no earlier than 2004-12-08 | N3 | 8944h | 6260.8h |  | 29.163 | Rel-6 |  |  |  |  |  |  |  |
| 100 | 11.7.3 | Interworking for IPv6 to IPv4 (SIP / SDP aspects) | 87d? | 2004-05-11 A | 2004-09-08 A | 100% |  | 2004-05-11 | 2004-09-08 | 87d? |  | finish no earlier than 2004-09-08 | N1 | 696h | 696h |  |  | Rel-6 |  |  |  |  |  |  |  |
| 101 | 16.8.1 | stage 3 of interworking with non-IMS IP networks | 911d | 2001-03-14 A | 2004-09-08 A | 100% |  | 2001-03-14 | 2004-09-08 | 911d |  | finish no earlier than 2004-09-08 | N1 | 7288h | 7288h |  |  | Rel-6 |  |  |  |  |  |  |  |
| 102 | 16.6.1 | Interworking between IMS and CS networks | 929d? | 2000-08-28 A | 2004-03-18 A | 100% |  | 2000-08-28 | 2004-03-18 | 929d? |  | finish no earlier than 2004-03-18 | N3 | 7432h | 7432h | IMS-CCR-IWCS | 29.163, 29.061, 24.228, and new CN4 specification | Rel-6 | TSG |  | Brendan Mc Williams, Vodafone | brendan.mcwilliams@vf.vodafone.co.uk | CCaR |  |  |
| 103 | 16.10 | Mn interface (IM-MGW to MGCF) enhancements (CN4 Part) | 418d | 2001-08-07 A | 2004-09-01 | 85% | 62.7d | 2001-08-07 | 2004-09-01 | 418d | 465d | finish no earlier than 2004-09-01 | N4 | 3344h | 2842.4h | IMS-CCR-Mn |  | Rel-6 |  |  |  |  |  |  |  |
| 104 | 11.10 | Study of subscriber and operators relationship in IMS and related ISIM requirements for Rel 6” | 20d? | 2002-11-15 A | 2002-12-12 A | 100% |  | 2002-11-15 | 2002-12-12 | 20d? |  | finish no earlier than 2002-12-12 | S1 | 160h | 160h |  |  | Rel-6 |  |  | Juha Kalliokulju (Nokia) | juha.kalliokulju@nokia.com |  |  |  |
| 105 | 11.11 | Lawful Interception in the 3GPP Rel-6 architecture | 269d? | 2002-12-09 A | 2003-12-18 A | 100% |  | 2002-12-09 | 2003-12-18 | 269d? |  | finish no earlier than 2003-12-18 | S3 | 2152h | 2152h | SEC1-LI | 33.106, 33.107, 33.108 | Rel-6 | TSG |  | Berthold Wilhelm | Berthold.Wilhelm@REGTP.DE |  |  |  |
| 106 | 11.12 | IMS Subscription and access scenarios | 130d? | 2002-12-16 A | 2003-06-13 A | 100% |  | 2002-12-16 | 2003-06-13 | 130d? |  | start no earlier than 2002-12-16 | S1 | 1040h | 1040h |  | 22.800 | Rel-6 |  |  |  |  |  |  |  |
| 107 | 11.13 | IMS charging | 455d? | 2003-03-21 A | 2004-12-16 A | 100% |  |  |  |  |  | finish no earlier than 2004-12-16 | S5 | 3640h | 3640h | IMS2-CH | 32.260 | Rel-6 | TSG |  |  |  |  |  |  |
| 108 | 11.14 | IMS Management objects | 1d? | 2000-01-03 A | 2000-01-03 | 79% | 0.21d? |  |  |  | 1682d |  | N1 | 8h | 6.32h |  | New TS 24.167 | Rel-6 | WG |  |  |  |  |  |  |
| 109 | 11.15 | Deleted - Stage 2 of IMS Phase 2 | 275d? | 2002-09-02 A | 2003-09-19 | 80% | 55d? |  |  |  | 713d | finish no earlier than 2003-09-19 | S2 | 2200h | 1760h |  |  | Rel-6 |  |  |  |  |  |  | SP-24 |

Notes:
- 77: Not yet available: verbally approved at SA15, actual WID to be provided at SA16 by Lucent
- 78: 29/05/2003 CN4: New WID presented for approval at CN#20...............
- 82: Depends on CN decision on CPCP in Rel-6. Complete, if unresolved IETF dependencies are dropped (-> LS to CN plenary)
- 85: Depends on CN decision on IETF dependencies in Rel-6. Higher figure if CPCP is dropped (-> LS to CN plenary)
- 92: Updated according to SP-040232
- 97: [DAB 14.02.02] - end date pushed back to March 2003
- 98: [DAB - 20.08.03] - CN Part of TR Complete @ CN#20
- 102: [DAB - 25.05.04] - CN3 consider this work to be complete
- 103: [CN4] 17th May 2002, CN4; Will be handled in Rel-6............
- 107: SA#26 12/2004 completed

| ID | WBS | Task | Duration | Start | Finish | Complete | Remaining | Baseline start | Baseline finish | Baseline duration | Total slack | Constraint | Resources | Work | Actual work | Text1 | Text3 | Text4 | Text6 | Text7 | Text8 | Text10 | Text5 | Text2 | Text9 |
| --- | --- | --- | --- | --- | --- | --- | --- | --- | --- | --- | --- | --- | --- | --- | --- | --- | --- | --- | --- | --- | --- | --- | --- | --- | --- |
| 110 | 12 | **3GPP Enablers for services like Push to Talk over Cellular (PoC)** | 459d? | 2003-09-08 A | 2005-06-09 | 88% | 55.34d? | 2003-09-08 | 2004-12-30 | 344d? | 264d |  | S2 | 10360h | 9110.85h | PoC | 23.979 | Shabnam Sultana, Ericsson | Rel-6 | TSG | Sang-Ui |  |  |  |  |
| 111 | 12.1 | Feasibility Study | 322d? | 2003-09-08 A | 2004-11-30 A | 100% |  | 2003-09-08 | 2004-11-30 | 322d? |  | finish no earlier than 2004-11-30 | S2 | 2576h | 2576h | PoC | 23.979 | Shabnam Sultana, Ericsson | Rel-6 |  |  | SP-24 |  |  |  |
| 112 | 12.2 | Dependencies on OMA PoC | 261d? | 2004-01-01 A | 2004-12-30 | 75% | 64d? | 2004-01-01 | 2004-12-30 | 261d? | 379d | finish no earlier than 2004-12-30 | OMA | 2088h | 1576h | PoC |  |  | Rel-6 | n/a |  | SP-24 | OMA-LIAISON@mail.openmobilealliance.org |  |  |
| 113 | 12.3 | Selection of one or more PoC codec(s) for PoC | 69d? | 2004-09-13 A | 2004-12-16 A | 100% |  |  |  |  |  | start no earlier than 2004-09-13 | S4 | 552h | 552h | PoC | 26.235, 26.236 |  | R6 | TSG | Paolo | SP-25 |  |  |  |
| 114 | 12.4 | PoC charging | 184d? | 2004-09-27 A | 2005-06-09 | 80% | 36.8d? |  |  |  | 264d | finish no earlier than 2005-06-09 | S5 | 1472h | 1177.6h | PoC-CH | 32.272 |  | Rel-6 | TSG |  |  |  |  |  |
| 115 | 13 | Interworking aspects and migration scenarios for IPv4 based IMS Implementations (Study) | 210d? | 2003-09-08 A | 2004-06-25 A | 100% |  | 2003-09-08 | 2004-06-25 | 210d? |  | finish no earlier than 2004-06-25 | S2 | 1680h | 1680h | IPv4IMS | 23.881 | Alexander Milinski, Siemens | Rel-6 |  | Sang-Ui |  |  |  |  |
| 116 | 16.3 | **Interoperability and Commonality between IMS using different "IP-connectivity Networks"** | 325d? | 2002-09-16 A | 2003-12-12 A | 100% |  | 2002-09-16 | 2003-12-12 | 325d? |  |  | S2 | 9176h | 9176h | IMSCOOP | 23.864 |  | Rel-6 | TSG | Sang-Ui |  |  |  |  |
| 117 | 16.3.1 | Stage 2 for Interoperability | 272d | 2002-09-16 A | 2003-09-30 A | 100% |  | 2002-09-16 | 2003-09-30 | 272d |  | finish no earlier than 2003-09-30 | S2 | 2176h | 2176h |  | 23.864 | Balazs Beternyi, Nokia | Rel-6 |  |  |  |  |  |  |
| 118 | 14.2 | Stage 2 for commonality | 265d? | 2002-09-16 A | 2003-09-19 A | 100% |  | 2002-09-16 | 2003-09-19 | 265d? |  | start no earlier than 2002-09-16 | S2 | 2120h | 2120h |  | 23.864 | Balazs Beternyi, Nokia | Rel-6 |  |  |  |  |  |  |
| 119 | 16.3.2 | Stage 3 | 305d | 2002-10-14 A | 2003-12-12 A | 100% |  | 2002-10-14 | 2003-12-12 | 305d |  | finish no earlier than 2003-12-12 | N1 | 2440h | 2440h |  |  | Keith Drage, Lucent | Rel-6 |  |  |  | drage@lucent.com |  |  |
| 120 | 17 | **Support of Push Services** | 823d | 2001-01-03 A | 2004-02-27 A | 100% |  | 2001-01-03 | 2004-02-27 | 823d |  |  | S1 | 11390.6h | 11390.6h | PUSH | 23.976 | Yoshinori Kitada, NTT Comware | Rel-6 | TSG | Sang-Ui |  |  | CCaR | 1365 |
| 121 | 17.1 | Stage 1 | 378d | 2001-01-03 A | 2002-06-14 A | 100% |  | 2001-01-03 | 2002-06-14 | 378d |  | finish no earlier than 2002-06-14 | S1 | 3024h | 3024h |  |  |  | Rel-6 |  |  |  |  |  |  |
| 122 | 17.3 | TR 23.976 on Push Architecture | 340d | 2002-11-11 A | 2004-02-27 A | 100% |  | 2002-11-11 | 2004-02-27 | 340d |  | finish no earlier than 2004-02-27 | S2 | 2720h | 2720h |  | 23.976 | Nick Alfano, RIM | Rel-6 |  |  |  |  |  |  |
| 123 | 18 | **Multimedia Messaging (MMS) enhancements** | 676d? | 2002-08-15 A | 2005-03-17 | 84% | 110.49d? | 2002-08-15 | 2004-09-16 | 546d? | 324d |  | T2 | 30216h | 25651.3h | MMS6 |  | Josef Laumen, Siemens | Rel-6 | TSG | Friedhelm |  | Josef.Laumen@SAL.SIEMENS.DE | Mes |  |
| 124 | 18.1 | **Definition of service requirements** | 286d? | 2002-11-15 A | 2003-12-19 A | 100% |  | 2002-11-15 | 2003-12-19 | 286d? |  |  | S1 | 4576h | 4576h | MMS6-SR | 22.140 |  | Rel-6 |  |  |  |  |  |  |
| 125 | 16.1.1 | Definition of service requirements charging | 286d? | 2002-11-15 A | 2003-12-19 A | 100% |  | 2002-11-15 | 2003-12-19 | 286d? |  | finish no earlier than 2003-12-20 | S1 | 2288h | 2288h |  | 22.140 | Josef Laumen, Siemens | Rel-6 |  |  |  | Josef.Laumen@SAL.SIEMENS.DE |  |  |
| 126 | 18.2 | Technical realization | 591d | 2002-09-06 A | 2004-12-10 A | 100% |  | 2002-09-06 | 2004-09-10 | 526d |  | finish no earlier than 2004-12-10 | T2 | 4728h | 4728h |  | 23.140 | Josef Laumen, Siemens | Rel-6 | TSG | Friedhelm |  | Josef.Laumen@SAL.SIEMENS.DE |  |  |
| 127 | 18.3 | OMA dependencies | 346d | 2003-08-15 A | 2004-12-10 | 30% | 242.2d | 2003-08-15 | 2004-08-27 | 228.85d | 393d | finish no earlier than 2004-12-10 | OMA | 2768h | 830.4h |  | OMA specs |  | Rel-6 | n/a | Friedhelm |  |  |  |  |
| 128 | 18.4 | MMS formats and codecs | 676d | 2002-08-15 A | 2005-03-17 | 95% | 33.8d | 2002-08-15 | 2004-09-16 | 546d | 324d | finish no earlier than 2005-03-17 | S4 | 5408h | 5137.6h | MMS6-Codec | 26.140 | Roberto Castagno (Nokia) | Rel-6 |  | Paolo |  | roberto.castagno@nokia.com |  |  |
| 129 | 16.5 | Handling of private addressing schemes in MMS | 263d | 2003-12-10 A | 2004-12-10 A | 100% |  | 2003-12-10 | 2004-06-04 | 128d |  | finish no earlier than 2004-12-10 | T2 | 2104h | 2104h |  | 23.140 | Steffen Habermann, T-Mobile | Rel-6 | TSG | Friedhelm |  | Steffen.Habermann@T-MOBILE.DE |  |  |
| 130 | 16.6 | Deleted - FS Multiple MMS Relay/Server Architecture | 263d | 2003-12-10 A | 2004-12-10 | 30% | 184.1d | 2003-12-10 | 2004-06-04 | 128d | 393d | finish no earlier than 2004-12-10 | T2 | 2104h | 631.2h |  | probably Annex to 23.140 | Juan Gorospe, Telefónica Móviles | Rel-6 | TSG | Friedhelm |  | gorospe_j@tsm.es |  |  |
| 131 | 16.7 | MMS charging | 390d? | 2003-03-21 A | 2004-09-16 A | 100% |  |  |  |  |  | start no earlier than 2003-03-21 | S5 | 3120h | 3120h | MMS6-CH | 32.270 |  | Rel-6 | TSG |  |  |  |  |  |
| 132 | 19 | **Rel-6 MExE enhancements** | 326d | 2002-03-08 A | 2003-06-06 A | 100% |  | 2002-03-08 | 2003-06-06 | 326d |  |  | T2 | 7328h | 7328h | MEXE6 |  |  | Rel-6 | TSG | Friedhelm |  |  | Ter |  |
| 133 | 19.1 | MExE Rel-6 Improvements and Investigations | 264d | 2002-03-08 A | 2003-03-12 A | 100% |  | 2002-03-08 | 2003-03-12 | 264d |  | finish no earlier than 2003-03-12 | T2 | 2112h | 2112h | MEXE6-ENHANC | 22.057, 23.057 | Lars Brenk (TTPCom) | Rel-6 | TSG |  |  | lsb_ttpcom@HOTMAIL.COM | Ter |  |
| 134 | 19.2 | MExE Run-Time Independent Framework Feasibility Study | 326d | 2002-03-08 A | 2003-06-06 A | 100% |  | 2002-03-08 | 2003-06-06 | 326d |  | finish no earlier than 2003-06-06 | T2 | 2608h | 2608h | MEXE6-RTIF | 22.857 | Aaron Cohen (Intel) | Rel-6 | TSG |  |  | Aaron.Cohen@intel.com | Ter |  |
| 135 | 21 | Subscription Management | 650d | 2002-09-20 A | 2005-03-17 | 95% | 32.5d | 2002-09-20 | 2004-09-16 | 520d | 324d | finish no earlier than 2005-03-17 | S5 | 5200h | 4940h | SuM | 32.140/1, 32.171/2/5, 32.803 | Istvan ABA (T-Mobile Austria) | Rel-6 | TSG | Adrian |  | istvan.aba@t-mobile.at |  |  |

Notes:
- 112: Updated according to SP-040232
- 113: Completed
- 114: SA#26: Target 06/2005 completed
- 117: No contributions assumed that no more will be done in 3GPP hence work may need to be done in 3GPP2
- 120: AS: Changed from FS to actual support of Push
- 130: originally it was intended to create a FS TR but most likely the work will become an Annex of 23.140
- 131: SA#25 09/2004 completed
- 135: TSG#26: Updated WID SP-040763 was SP-020448

| ID | WBS | Task | Duration | Start | Finish | Complete | Remaining | Baseline start | Baseline finish | Baseline duration | Total slack | Constraint | Resources | Work | Actual work | Text1 | Text4 | Text6 | Text7 | Text8 | Text9 | Text5 | Text3 |
| --- | --- | --- | --- | --- | --- | --- | --- | --- | --- | --- | --- | --- | --- | --- | --- | --- | --- | --- | --- | --- | --- | --- | --- |
| 136 | 22 | **Presence Capability** | 1044d? | 2001-03-19 A | 2005-03-17 | 73% | 281.93d? | 2001-03-19 | 2004-12-31 | 990d? | 324d |  | S1 | 33032h | 24111.8h | PRESNC | Mark Cataldo, Motorola | Rel-6 | TSG | Michael | 11004 |  |  |
| 137 | 22.1 | Stage 1 | 610d | 2001-03-19 A | 2003-07-18 A | 100% |  | 2001-03-19 | 2003-07-18 | 610d |  | finish no earlier than 2003-07-18 | S1 | 4880h | 4880h |  |  | Rel-6 |  |  | 11005 |  |  |
| 138 | 22.2 | Stage 2 | 268d | 2001-09-12 A | 2002-09-20 A | 100% |  | 2001-09-12 | 2002-09-20 | 268d |  | finish no earlier than 2002-09-20 | S2 | 2144h | 2144h |  | Balazs BERTENYI, Nokia | Rel-6 | TSG |  |  | Balazs.Bertenyi@nokia.com |  |
| 139 | 22.3 | Stage 3 | 703d | 2002-04-01 A | 2004-12-08 | 95% | 35.15d | 2002-04-01 | 2004-09-08 | 638d | 395d | finish no earlier than 2004-12-08 | N1 | 5624h | 5342.8h |  | Keith Drage, Lucent | Rel-6 |  |  |  | drage@lucent.com |  |
| 140 | 19.4 | Stage 3 (CN3 Part Pk interface) | 703d? | 2002-04-01 | 2004-12-08 |  |  | 2002-04-01 | 2004-09-08 | 638d? | 395d | finish no earlier than 2004-12-08 | N3 | 5624h |  |  |  | Rel-6 |  |  |  |  |  |
| 141 | 19.5 | Media Codecs and Formats for IMS Messaging and Presence | 461d? | 2003-06-12 A | 2005-03-17 | 95% | 23.05d? | 2003-06-12 | 2004-09-16 | 331d? | 324d | finish no earlier than 2005-03-17 | S4 | 3688h | 3503.6h | PRESNC-COFIMP | Harri Honko (Nokia) | Rel-6 | TSG | Paolo |  | harri.honko@nokia.com | TS 26.141 |
| 142 | 22.4 | Security issues | 79d | 2002-08-26 A | 2002-12-12 | 90% | 7.9d | 2002-08-26 | 2002-12-12 | 79d | 914d | finish no earlier than 2002-12-12 | S3 | 632h | 568.8h |  |  | Rel-6 |  |  |  |  |  |
| 143 | 19.7 | SIMPLE Presence | 261d? | 2004-01-01 A | 2004-12-30 | 75% | 64d? | 2004-01-01 | 2004-11-30 | 239d? | 379d | finish no earlier than 2004-12-30 | OMA | 2088h | 1576h |  |  | Rel-6 | n/a |  |  | OMA-LIAISON@mail.openmobilealliance.org |  |
| 144 | 25 | **Enhanced A/Gb feasibility study** | 51d? | 2002-08-30 A | 2002-11-08 A | 100% |  | 2002-08-30 | 2002-11-08 | 51d? |  |  | GP | 3264h | 3264h | AGbEnFS | J-L Carrizo, Vodafone | Rel-6 | TSG | Paolo |  | jose-luis.carrizo@vodafone.co.uk |  |
| 145 | 25.1 | **Feasibility study on A/Gb enhancements** | 51d? | 2002-08-30 A | 2002-11-08 A | 100% |  | 2002-08-30 | 2002-11-08 | 51d? |  |  | G2 | 2856h | 2856h | AGbEnFS-FS |  | Rel-6 | TSG |  |  |  |  |
| 146 | 25.1.1 | Requirements for the support of conversational services | 51d | 2002-08-30 A | 2002-11-08 A | 100% |  | 2002-08-30 | 2002-11-08 | 51d |  | finish no earlier than 2002-11-08 | GP | 408h | 408h |  |  | Rel-6 |  |  |  |  |  |
| 147 | 20.1.2 | Identification of the different building blocks for the provision of conversational services on the existing A/Gb protocol stack | 51d? | 2002-08-30 A | 2002-11-08 A | 100% |  | 2002-08-30 | 2002-11-08 | 51d? |  | finish no earlier than 2002-11-08 | GP | 408h | 408h |  |  | Rel-6 |  |  |  |  |  |
| 148 | 20.1.3 | Outline of impact and feasibility of these building blocks and their different solutions | 51d? | 2002-08-30 A | 2002-11-08 A | 100% |  | 2002-08-30 | 2002-11-08 | 51d? |  | finish no earlier than 2002-11-08 | GP | 408h | 408h |  |  | Rel-6 |  |  |  |  |  |
| 149 | 25.1.4 | Impact on 3GPP architecture and requirement to co-ordinatge with other TSGs (CN, SA) | 51d | 2002-08-30 A | 2002-11-08 A | 100% |  | 2002-08-30 | 2002-11-08 | 51d |  | finish no earlier than 2002-11-08 | GP | 408h | 408h |  |  | Rel-6 |  |  |  |  |  |
| 150 | 25.1.5 | Standardisation effort | 51d | 2002-08-30 A | 2002-11-08 A | 100% |  | 2002-08-30 | 2002-11-08 | 51d |  | finish no earlier than 2002-11-08 | GP | 408h | 408h |  |  | Rel-6 |  |  |  |  |  |
| 151 | 25.1.6 | Dependency to other features | 51d | 2002-08-30 A | 2002-11-08 A | 100% |  | 2002-08-30 | 2002-11-08 | 51d |  | finish no earlier than 2002-11-08 | GP | 408h | 408h |  |  | Rel-6 |  |  |  |  |  |
| 152 | 26 | **Flexible Layer One for GERAN** | 1325d | 2000-01-03 A | 2005-01-28 | 92% | 108.79d | 2000-01-03 | 2004-06-25 | 1170d | 358d |  | GP | 85063h | 64605.3h | FLOGER | Benoist Sébire | Rel-6 | TSG | Paolo |  | benoist.sebire@nokia.com |  |
| 153 | 26.1 | **Realisation of a Flexible Layer One** | 1125d | 2000-01-03 A | 2004-04-23 A | 100% |  | 2000-01-03 | 2004-04-23 | 1125d |  |  | GP | 42808h | 42808h | FLOGER-Real | Benoist Sébire | Rel-6 |  |  |  | benoist.sebire@nokia.com |  |
| 154 | 26.1.1 | Technical Report | 471d | 2002-04-19 A | 2004-02-06 A | 100% |  | 2002-04-19 | 2004-02-06 | 471d |  | finish no earlier than 2004-02-06 | GP | 3768h | 3768h |  |  | Rel-6 |  |  |  |  |  |
| 155 | 26.1.2 | Architecture in 45.001 and 43.051 | 526d | 2002-04-19 A | 2004-04-23 A | 100% |  | 2002-04-19 | 2004-04-23 | 526d |  | finish no earlier than 2004-04-23 | G1 | 4208h | 4208h |  |  | Rel-6 |  |  |  |  |  |
| 156 | 26.1.3 | Multiplexing in 45.002 | 526d | 2002-04-19 A | 2004-04-23 A | 100% |  | 2002-04-19 | 2004-04-23 | 526d |  | finish no earlier than 2004-04-23 | G1 | 4208h | 4208h |  |  | Rel-6 |  |  |  |  |  |
| 157 | 26.1.4 | Channel Coding in 45.003 | 526d | 2002-04-19 A | 2004-04-23 A | 100% |  | 2002-04-19 | 2004-04-23 | 526d |  | finish no earlier than 2004-04-23 | G1 | 4208h | 4208h |  |  | Rel-6 |  |  |  |  |  |
| 158 | 26.1.5 | Performance Requirements in 45.005 | 1125d | 2000-01-03 A | 2004-04-23 A | 100% |  | 2000-01-03 | 2004-04-23 | 1125d |  | finish no earlier than 2004-04-23 | G1 | 9000h | 9000h |  |  | Rel-6 |  |  |  |  |  |
| 159 | 26.1.6 | Radio subsystem link control in 45.008 | 526d | 2002-04-19 A | 2004-04-23 A | 100% |  | 2002-04-19 | 2004-04-23 | 526d |  | finish no earlier than 2004-04-23 | G1 | 4208h | 4208h |  |  | Rel-6 |  |  |  |  |  |
| 160 | 26.1.7 | Requirements in 44.004 | 526d | 2002-04-19 A | 2004-04-23 A | 100% |  | 2002-04-19 | 2004-04-23 | 526d |  | finish no earlier than 2004-04-23 | G2 | 4208h | 4208h |  |  | Rel-6 |  |  |  |  |  |

Notes:
- 136: A Sultan merged "Presence Service Enhancements" (UID31028, PRES1) to this feature as no answer was provided on why Presence and Presence Encmts had same target completion date
- 139: Dependency to 2 IETF drafts, no known work at the moment
- 140: No Contributions so far - only requires a little work
- 141: Also for 31022 IMS Messaging
- 142: LSs handled in SA3. WID approved SA#17 Contribution at S3#25 & following e-mail discussion.
- 143: Updated according to SP-040232
- 144: Closed
- 152: Nokia, Ericsson, Siemens, Telia
- 153: Completed

| ID | WBS | Task | Duration | Start | Finish | Complete | Remaining | Baseline start | Baseline finish | Baseline duration | Total slack | Constraint | Resources | Work | Actual work | Text1 | Text4 | Text5 | Text6 | Text3 | Text8 | Text7 | Text9 | Text12 |
| --- | --- | --- | --- | --- | --- | --- | --- | --- | --- | --- | --- | --- | --- | --- | --- | --- | --- | --- | --- | --- | --- | --- | --- | --- |
| 161 | 26.2 | **Signalling and protocol support for a Flexible Layer One** | 571d | 2002-04-19 A | 2004-06-25 A | 100% |  | 2002-04-19 | 2004-06-25 | 571d |  |  | G2 | 13704h | 13704h | FLOGER-SigPro | Benoist Sébire | benoist.sebire@nokia.com | Rel-6 |  |  |  |  |  |
| 162 | 26.2.1 | Modifications to RLC/MAC in 44.060 and 44.160 | 571d | 2002-04-19 A | 2004-06-25 A | 100% |  | 2002-04-19 | 2004-06-25 | 571d |  | finish no earlier than 2004-06-25 | G2 | 4568h | 4568h |  |  |  | Rel-6 |  |  |  |  |  |
| 163 | 26.2.2 | Modifications to RRC in 44.118 and 44.018 | 571d | 2002-04-19 A | 2004-06-25 A | 100% |  | 2002-04-19 | 2004-06-25 | 571d |  | finish no earlier than 2004-06-25 | G2 | 4568h | 4568h |  |  |  | Rel-6 |  |  |  |  |  |
| 164 | 26.3 | **Security for a Flexible Layer One** | 356d | 2002-04-19 A | 2003-08-29 A | 100% |  | 2002-04-19 | 2003-08-29 | 356d |  |  | S3, G2 | 5663.04h | 5663.04h | FLOGER-SecFLO | Benoist Sébire | benoist.sebire@nokia.com | Rel-6 |  |  |  |  |  |
| 165 | 26.3.1 | Ciphering in 44.160,44.118, 44.060 and 44.018 | 356d | 2002-04-19 A | 2003-08-29 A | 100% |  | 2002-04-19 | 2003-08-29 | 356d |  | finish no earlier than 2003-08-29 | S3, G2 | 2848h | 2848h |  |  |  | Rel-6 |  |  |  |  |  |
| 166 | 26.4 | **GERAN MS Conformance test for the Flexible Layer One** | 256d | 2004-02-06 | 2005-01-28 |  |  | 2004-02-06 | 2004-06-25 | 101d | 358d |  | G4; G5 | 8192h |  | FLOGER-Msconf | Benoist Sébire | benoist.sebire@nokia.com | Rel-6 |  |  |  |  |  |
| 167 | 26.4.1 | MS Test in 51.010 | 256d | 2004-02-06 | 2005-01-28 |  |  | 2004-02-06 | 2004-06-25 | 101d | 358d | finish no earlier than 2005-01-28 | G4; G5 | 4096h |  |  |  |  | Rel-6 |  |  |  |  |  |
| 168 | 26.5 | **GERAN BTS Conformance test for the Flexible Layer One** | 256d | 2004-02-06 | 2005-01-28 |  |  | 2004-02-06 | 2004-06-25 | 101d | 358d |  | G3 | 4096h |  | FLOGER-BTSconf | Benoist Sébire | benoist.sebire@nokia.com | Rel-6 |  |  |  |  |  |
| 169 | 26.5.1 | BTS Test in 51.021 | 256d | 2004-02-06 | 2005-01-28 |  |  | 2004-02-06 | 2004-06-25 | 101d | 358d | finish no earlier than 2005-01-28 | G3 | 2048h |  |  |  |  | Rel-6 |  |  |  |  |  |
| 170 | 27 | Uplink TDOA feasibility study | 151d | 2001-11-30 A | 2002-06-28 A | 100% |  | 2001-11-30 | 2002-06-28 | 151d |  | finish no earlier than 2002-06-28 | GP | 1208h | 1208h | TDOAF | Bob Gross, TruePosition, Inc. | rlgross@trueposition.com | Rel-6 | 45.811 | Paolo |  |  |  |
| 171 | 28 | **Multimedia Broadcast and Multicast Service** | 1134d? | 2001-05-11 A | 2005-09-15 | 80% | 223.79d? | 2001-05-11 | 2004-12-16 | 940d? | 195d |  | S1 | 132386h | 91345.4h | MBMS |  |  | Rel-6 |  | Michael | TSG |  |  |
| 172 | 28.1 | Stage 1 | 232d | 2001-05-11 A | 2002-04-01 A | 100% |  | 2001-05-11 | 2002-04-01 | 232d |  | finish no earlier than 2002-04-01 | S1 | 1856h | 1856h |  |  |  | Rel-6 | 22.146, 22.101 |  |  | 11003 |  |
| 173 | 28.2 | **Stage 2** | 648d | 2001-09-24 A | 2004-03-17 | 99% | 0d | 2001-09-24 | 2004-03-17 | 648d | 0d |  | S2 | 10408h | 6548.8h |  |  |  | Rel-6 |  |  | TSG |  |  |
| 174 | 28.2.1 | TR on Architectural Study | 240d | 2001-09-24 A | 2002-08-23 A | 100% |  | 2001-09-24 | 2002-08-23 | 240d |  | finish no earlier than 2002-08-23 | S2 | 1920h | 1920h |  |  |  | Rel-6 | 23.846 |  |  |  |  |
| 175 | 28.2.2 | Stage 2 Specification Work | 413d | 2002-08-19 A | 2004-03-17 A | 100% |  | 2002-08-19 | 2004-03-17 | 413d |  | finish no earlier than 2004-03-17 | S2 | 3304h | 3304h |  |  |  | Rel-6 | 23.246 |  |  |  |  |
| 176 | 28.3 | **Introduction of MBMS in RAN** | 967d? | 2002-01-01 A | 2005-09-15 | 77% | 220.1d? | 2002-01-01 | 2004-09-15 | 707d | 195d |  | R2 | 15992h | 11311.2h | MBMS-RAN | Juho Pirskanen , Nokia | juho.pirskanen@nokia.com | Rel-6 | TS 25.346, TS 25.304, 25.321, 25.322, 25.323, 25.331 | MCC_RAN | TSG | 2481 |  |
| 177 | 23.3.1 | Introduction of MBMS in RAN (physical & upper layers, access network interfaces) | 771d? | 2002-01-01 A | 2004-12-14 A | 100% |  |  |  |  |  | finish no earlier than 2004-12-14 | R2 | 6168h | 6168h | MBMS-RAN | Juho Pirskanen , Nokia | juho.pirskanen@nokia.com | Rel-6 | TS 25.346, TS 25.304, 25.321, 25.322, 25.323 | MCC_RAN | TSG |  |  |
| 178 | 23.3.2 | UE Performance Requirements for MBMS | 261d? | 2004-09-15 A | 2005-09-15 | 10% | 234.9d? |  |  |  | 195d | finish no earlier than 2005-09-15 | R4 | 2088h | 208.8h | MBMS-RAN-RF | Torgny Palenius, Ericsson | Torgny.Palenius@ericsson.com | Rel-6 | TS25.101, TS25.133 | MCC_RAN | TSG |  |  |
| 179 | 28.4 | Support of the MBMS in CN protocols | 647d | 2002-06-18 A | 2004-12-08 A | 100% |  | 2002-06-18 | 2004-09-08 | 582d |  | finish no earlier than 2004-12-08 | N1 | 5176h | 5176h |  |  |  | Rel-6 |  |  | TSG |  |  |
| 180 | 23.5 | Gmb interface for MBMS (CN3 part) | 334d | 2003-08-29 A | 2004-12-08 | 85% | 50.1d | 2003-08-29 | 2004-09-10 | 271d | 395d | finish no earlier than 2004-12-08 | N3 | 2672h | 2271.2h |  |  |  | Rel-6 | 29.061 |  |  |  |  |
| 181 | 28.5 | Security Aspects of MBMS | 710d | 2002-07-01 A | 2005-03-18 | 95% | 35.5d | 2002-07-01 | 2003-09-25 | 324d | 323d | finish no earlier than 2005-03-18 | S3 | 5680h | 5396h | MBMS | Escott, Adrian, 3 | adrian.escott@three.co.uk | Rel-6 |  |  | TSG |  |  |
| 182 | 28.6 | **Support of MBMS in GERAN** | 892d? | 2001-08-30 A | 2005-01-28 | 76% | 211.08d? | 2001-08-30 | 2004-11-12 | 837d? | 358d |  | GP | 71528h | 50933.9h | MBMS-GERAN |  |  | Rel-6 |  |  | TSG |  |  |
| 183 | 28.6.1 | Impact on the logical and physical channels | 631d | 2002-08-30 A | 2005-01-28 | 85% | 94.65d | 2002-08-30 | 2004-11-12 | 576d | 358d | finish no earlier than 2005-01-28 | GP | 5048h | 4290.8h |  |  |  | Rel-6 |  |  |  |  |  |
| 184 | 28.6.4 | Re-synchronisation at cell change | 631d | 2002-08-30 A | 2005-01-28 | 85% | 94.65d | 2002-08-30 | 2004-11-12 | 576d | 358d | finish no earlier than 2005-01-28 | G2 | 5048h | 4290.8h |  |  |  | Rel-6 |  |  |  |  |  |
| 185 | 23.7.3 | Simultaneous support of MBMS services | 631d? | 2002-08-30 A | 2005-01-28 | 85% | 94.65d? | 2002-08-30 | 2004-11-12 | 576d? | 358d | finish no earlier than 2005-01-28 | GP | 5048h | 4290.8h |  |  |  | Rel-6 |  |  |  |  |  |
| 186 | 23.7.4 | Simultaneous support of MBMS and non-MBMS services | 892d? | 2001-08-30 A | 2005-01-28 | 85% | 133.8d? | 2001-08-30 | 2004-11-12 | 837d? | 358d | finish no earlier than 2005-01-28 | GP | 7136h | 6065.6h |  |  |  | Rel-6 |  |  |  |  |  |
| 187 | 23.7.5 | Resynchronisation at cell change | 892d? | 2001-08-30 A | 2005-01-28 | 85% | 133.8d? | 2001-08-30 | 2004-11-12 | 837d? | 358d | finish no earlier than 2005-01-28 | GP | 7136h | 6065.6h |  |  |  | Rel-6 |  |  |  |  |  |
| 188 | 28.6.5 | Decision making process between point-to-point or pont-to-multipoint configurations | 631d | 2002-08-30 A | 2005-01-28 | 85% | 94.65d | 2002-08-30 | 2004-11-12 | 576d | 358d | finish no earlier than 2005-01-28 | GP | 5048h | 4290.8h |  |  |  | Rel-6 |  |  |  |  |  |
| 189 | 28.6.6 | MBMS channel allocations procedures to multiple MSs | 631d | 2002-08-30 A | 2005-01-28 | 85% | 94.65d | 2002-08-30 | 2004-11-12 | 576d | 358d | finish no earlier than 2005-01-28 | GP | 5048h | 4290.8h |  |  |  | Rel-6 |  |  |  |  |  |
| 190 | 28.6.7 | Changes to the Gb interface | 631d | 2002-08-30 A | 2005-01-28 | 85% | 94.65d | 2002-08-30 | 2004-11-12 | 576d | 358d | finish no earlier than 2005-01-28 | GP | 5048h | 4290.8h |  |  |  | Rel-6 |  |  |  |  |  |
| 191 | 28.6.8 | GERAN specific changes to the Iu-ps interface | 631d | 2002-08-30 A | 2005-01-28 | 85% | 94.65d | 2002-08-30 | 2004-11-12 | 576d | 358d | finish no earlier than 2005-01-28 | GP | 5048h | 4290.8h |  |  |  | Rel-6 |  |  |  |  |  |
| 192 | 28.6.9 | Interaction between MBMS and Iu-flex | 631d | 2002-08-30 A | 2005-01-28 | 85% | 94.65d | 2002-08-30 | 2004-11-12 | 576d | 358d | finish no earlier than 2005-01-28 | GP | 5048h | 4290.8h |  |  |  | Rel-6 |  |  |  |  |  |
| 193 | 28.6.10 | Security aspects | 631d | 2002-08-30 A | 2005-01-28 | 85% | 94.65d | 2002-08-30 | 2004-11-12 | 576d | 358d | finish no earlier than 2005-01-28 | GP | 5048h | 4290.8h |  |  |  | Rel-6 |  |  |  |  |  |
| 194 | 23.7.12 | MS conformance tests- G3 | 631d? | 2002-08-30 | 2005-01-28 |  |  | 2002-08-30 | 2004-11-12 | 576d? | 358d | finish no earlier than 2005-01-28 | G3 | 5048h |  |  |  |  | Rel-6 |  |  |  |  |  |
| 195 | 23.7.13 | Deleted - MS conformance tests - G5 | 216d? | 2002-08-30 | 2003-06-27 |  |  |  |  |  | 773d | finish no earlier than 2003-06-27 | G5 | 1728h |  |  |  |  | Rel-6 |  |  |  |  | GP-19 |

Notes:
- 161: Completed
- 164: Started
- 166: Under evaluation
- 168: Under evaluation
- 171: Title renamed at SA#13
- 172: This may or may not be a separate stage 1. In the meantime, CRs are proposed for 22.101
- 177: Was "Introduction of MBMS in RAN" before RP#25. Created w/o WIDS after RAN approved the WT for RF aspects.Take WIDS from the parent BB
- 178: Approved at RP#25 as RP-040370
- 181: WID approved SA#17. 2004-12: Expected completion March 2005

| ID | WBS | Task | Duration | Start | Finish | Complete | Remaining | Baseline start | Baseline finish | Baseline duration | Total slack | Constraint | Resources | Work | Actual work | Text3 | Text6 | Text8 | Text9 | Text1 | Text4 | Text5 | Text7 | Text10 | Text12 |
| --- | --- | --- | --- | --- | --- | --- | --- | --- | --- | --- | --- | --- | --- | --- | --- | --- | --- | --- | --- | --- | --- | --- | --- | --- | --- |
| 196 | 28.1 | **MBMS User Services** | 483d? | 2003-05-13 A | 2005-03-17 | 83% | 80.21d? | 2003-05-13 | 2004-12-16 | 418d? | 324d |  | S1 | 9416h | 7852.32h | 22.246 | Rel-6 | Michael | 11003 |  |  |  |  |  |  |
| 197 | 28.1 | MBMS User Services Stage 1 | 233d | 2003-05-13 A | 2004-04-01 A | 100% |  | 2003-05-13 | 2004-04-01 | 233d |  | start no earlier than 2003-05-13 | S1 | 1864h | 1864h | 22.246 | Rel-6 | Michael | 11003 |  |  |  |  |  |  |
| 198 | 23.8.2 | Definition of MBMS user services, media codecs, formats and transport/application protocols using MBMS | 461d? | 2003-06-12 A | 2005-03-17 | 75% | 115.25d? | 2003-06-12 | 2004-12-16 | 396d? | 324d | finish no earlier than 2005-03-17 | S4 | 3688h | 2766h | 26.346 | Rel-6 | Paolo |  | MBMS-TSMBMS | Igor Curcio (Nokia) | igor.curcio@nokia.com | TSG |  |  |
| 199 | 23.9 | MBMS charging | 108d? | 2005-01-11 | 2005-06-09 |  |  |  |  |  | 264d | start no earlier than 2005-01-11 | S5 | 864h |  | 32.273 | Rel-6 |  |  | MBMS-CH |  |  | WG |  |  |
| 200 | 29 | **Speech Recognition and Speech Enabled Services** | 974d? | 2001-10-08 A | 2005-06-30 | 73% | 264.55d? | 2001-10-08 | 2004-06-10 | 699d? | 249d |  | S1 | 19544h | 14235.6h |  | Rel-6 | Michael |  | SRSES |  |  | TSG |  |  |
| 201 | 29.1 | Speech Enabled Services Based on Distributed Speech Recognition (DSR) | 115d | 2001-10-08 A | 2002-03-15 A | 100% |  | 2001-10-08 | 2002-03-15 | 115d |  | finish no earlier than 2002-03-15 | S1 | 920h | 920h | 22.941, 23.207, 22.243 | Rel-6 |  |  | DSR | D Williams, QUALCOMM, Inc. | Dwilliams@qualcomm.com | TSG |  |  |
| 202 | 29.2 | TR on Architectural impacts | 212d | 2003-05-12 A | 2004-03-02 A | 100% |  | 2003-05-12 | 2004-03-02 | 212d |  | finish no earlier than 2004-03-02 | S2 | 1696h | 1696h | 23.877 | Rel-6 |  |  |  |  |  |  |  |  |
| 203 | 24.3 | Codec Work to Support Speech Recognition Framework for Automated Voice Services | 568d? | 2002-10-15 A | 2004-12-16 A | 100% |  | 2002-10-15 | 2004-06-10 | 433d? |  | finish no earlier than 2004-12-16 | S4 | 4544h | 4544h | 26.235, 26.236, 26.243, 26.177, 26.943 | Rel-6 | Paolo |  | SRSES-Codec | David Pearce, Motorola | bdp003@motorola.com | WG |  |  |
| 204 | 24.4 | Multimodal support | 391d? | 2004-01-01 A | 2005-06-30 | 45% | 216d? | 2004-01-01 | 2004-01-01 | 1d? | 249d | finish no earlier than 2005-06-30 | OMA | 3128h | 1400h |  | Rel-6 |  |  |  |  | OMA-LIAISON@mail.openmobilealliance.org |  | SP-24 |  |
| 205 | 24.5 | Deleted - SES codec negotiation at SDP | 183d? | 2002-09-23 | 2003-06-04 |  |  |  |  |  | 790d | finish no earlier than 2003-06-04 | N1 | 1464h |  |  | Rel-6 |  |  |  |  |  |  |  | NP-23 |
| 206 | 30 | **Generic User Profile** | 889d | 2001-10-08 A | 2005-03-03 | 65% | 312.15d | 2001-10-08 | 2004-11-30 | 822d | 334d |  | S1 | 28983.8h | 18806.8h |  | Rel-6 | Michael |  | GUP |  |  | TSG |  |  |
| 207 | 30.1 | Stage 1 - Requirements | 430d | 2001-10-08 A | 2003-05-30 A | 100% |  | 2001-10-08 | 2003-05-30 | 430d |  | finish no earlier than 2002-12-09 | S1 | 3440h | 3440h | 22.240, 22.228 | Rel-6 |  |  |  | Paul Amery (Orange) | paul.amery@orange.co.uk |  |  |  |
| 208 | 30.3 | Stage 2 - Architecture | 355d | 2002-01-28 A | 2003-06-06 A | 100% |  | 2002-01-28 | 2003-06-06 | 355d |  | finish no earlier than 2003-06-06 | S2 | 2840h | 2840h | 23.240 | Rel-6 |  |  |  | Harri KOSKINEN, Nokia | harri.o.koskinen@nokia.com |  |  |  |
| 209 | 30.2 | Stage 2 - Data Description Method | 586d | 2002-12-05 A | 2005-03-03 | 45% | 322.3d | 2002-12-05 | 2004-03-05 | 327d | 334d | finish no earlier than 2005-03-03 | N4 | 4688h | 2109.6h | 23.241 | Rel-6 | Friedhelm |  |  | Kurt Bischinger (T-Mobile AUSTRIA) | kurt.bischinger@t-mobile.at | TSG |  |  |
| 210 | 30.4 | Stage 3 - Common objects | 586d | 2002-12-05 A | 2005-03-03 | 40% | 351.6d | 2002-12-05 | 2004-09-03 | 457d | 334d | finish no earlier than 2005-03-03 | N4 | 4688h | 1875.2h | 24.241 | Rel-6 | Friedhelm |  |  |  |  | TSG |  |  |
| 211 | 30.5 | Stage 3 - Network | 468.98d | 2003-05-19 A | 2005-03-03 | 39% | 286.08d | 2003-05-19 | 2004-11-30 | 401.98d | 334d | finish no earlier than 2005-03-03 | N4 | 3751.84h | 1463.22h | 29.240 | Rel-6 |  |  |  |  |  |  |  |  |
| 212 | 30.6 | Security Aspects | 308d | 2002-07-16 A | 2003-09-18 A | 100% |  | 2002-07-16 | 2003-09-18 | 308d |  | finish no earlier than 2003-09-18 | S3 | 2464h | 2464h | 33.102, 33.203, 33.210 | Rel-6 |  |  |  | Owen, Bradley | bvowen@lucent.com | WG |  |  |
| 213 | 31 | **Digital Rights Management** | 690d? | 2001-10-08 A | 2004-05-28 | 95% | 34.97d? | 2001-10-08 | 2004-05-28 | 690d? | 533d |  | S1 | 11392h | 10814.6h |  | Rel-6 | Michael |  | DRM |  |  | TSG |  |  |
| 214 | 31.1 | Requirements | 179d | 2001-10-08 A | 2002-06-13 A | 100% |  | 2001-10-08 | 2002-06-13 | 179d |  | finish no earlier than 2002-06-13 | S1 | 1432h | 1432h |  | Rel-6 |  |  |  | Nicholas Wood, Openwave Systems | nicholas.wood@openwave.com |  |  |  |
| 215 | 26.2 | Deleted - Monitoring of Stages 2 and 3 progress (actual work to be done by OMA) | 155d? | 2002-08-19 A | 2003-03-21 A | 100% |  | 2002-08-19 | 2003-03-21 | 155d? |  | start no earlier than 2002-08-19 | S1 | 1240h | 1240h |  | Rel-6 |  |  |  |  |  |  |  |  |
| 216 | 26.3 | Stage 2 | 107d? | 2004-01-01 A | 2004-05-28 A | 100% |  | 2004-01-01 | 2004-05-28 | 107d? |  | finish no earlier than 2004-05-28 | OMA | 856h | 856h |  | Rel-6 |  |  |  |  | OMA-LIAISON@mail.openmobilealliance.org |  | SP-24 |  |
| 217 | 26.4 | Stage 3 | 107d? | 2004-01-01 A | 2004-05-28 A | 100% |  | 2004-01-01 | 2004-05-28 | 107d? |  | finish no earlier than 2004-05-28 | OMA | 856h | 856h |  | Rel-6 |  |  |  |  | OMA-LIAISON@mail.openmobilealliance.org |  | SP-24 |  |
| 218 | 31.3 | Security | 186d | 2002-06-17 A | 2003-03-03 | 80% | 37.2d | 2002-06-17 | 2003-03-03 | 186d | 857d | finish no earlier than 2003-03-03 | OMA | 1488h | 1190.4h |  | Rel-6 |  |  |  |  |  |  |  |  |
| 219 | 32 | **WLAN-UMTS Interworking** | 1419d? | 2000-01-03 A | 2005-06-09 | 94% | 80.92d? | 2000-01-03 | 2004-09-30 | 1239d? | 264d |  | S1 | 45056h | 42539.1h |  | Rel-6 | Michael |  | WLAN | Fredric Paint, Telenor | frederic.paint@telenor.com | TSG |  |  |
| 220 | 32.1 | Technical Report | 900d? | 2000-01-03 A | 2003-06-13 A | 100% |  | 2000-01-03 | 2003-06-13 | 900d? |  | finish no earlier than 2003-06-13 | S1 | 7200h | 7200h | 22.934, 22.101, 22.105 | Rel-6 |  |  | WLAN-TR | Fredric Paint, Telenor | frederic.paint@telenor.com |  |  |  |

Notes:
- 199: SA#26: Approved WID SP-040778. Target TS Approval 06/2005.
- 203: Completed
- 205: Abandoned NP-23
- 211: 17 May no activity in CN4............
- 212: WID approved SA#17. SA WG3 progress slow, depends on progress in other groups.
- 213: Foreseen start and completion dates introduced by MCC (no indication at all on the WID)
- 215: Replaced by UID 60005 and 60006
- 218: SA3 acknowledge role in WI at SA3#20. Active contribution S3#24, S3#25. S3 WID approved SA#17

| ID | WBS | Task | Duration | Start | Finish | Complete | Remaining | Baseline start | Baseline finish | Baseline duration | Total slack | Constraint | Resources | Work | Actual work | Text1 | Text3 | Text4 | Text5 | Text6 | Text10 | Text7 | Text8 | Text9 | Text11 |
| --- | --- | --- | --- | --- | --- | --- | --- | --- | --- | --- | --- | --- | --- | --- | --- | --- | --- | --- | --- | --- | --- | --- | --- | --- | --- |
| 221 | 27.2 | **Stage 1** | 375d? | 2003-01-06 A | 2004-06-11 | 83% | 64.48d? | 2000-01-03 | 2004-06-11 | 1160d? | 523d |  | S1 | 4840h | 4166h | WLAN-TS | 22.234 | Fredric Paint, Telenor | frederic.paint@telenor.com | Rel-6 | SP-24 |  |  |  |  |
| 222 | 27.2.1 | Global stage 1 | 375d? | 2003-01-06 A | 2004-06-11 | 99% | 3.75d? |  |  |  | 523d | finish no earlier than 2004-06-11 | S1 | 3000h | 2970h | WLAN-TS | 22.234 | Fredric Paint, Telenor | frederic.paint@telenor.com | Rel-6 | SP-24 |  |  |  |  |
| 223 | 27.2.2 | Session Continuity | 115d? | 2004-01-05 A | 2004-06-11 | 30% | 80.5d? |  |  |  | 523d | start no earlier than 2004-01-05 | S1 | 920h | 276h | WLAN-SC |  |  |  | Rel-7 | SP-24 |  |  |  |  |
| 224 | 32.2 | Architecture Definition for scenarii 2 and 3 | 571d | 2002-03-25 A | 2004-05-31 A | 100% |  | 2002-03-25 | 2004-05-31 | 571d |  | finish no earlier than 2004-05-31 | S2 | 4568h | 4568h |  | 23.234 |  |  | Rel-6 |  | TSG |  |  |  |
| 225 | 32.3 | Security | 125d | 2002-09-30 A | 2003-03-21 A | 100% |  | 2002-09-30 | 2003-03-21 | 125d |  | finish no earlier than 2003-03-21 | S3 | 1000h | 1000h |  | 21.133, 33.106, 33.107, 33.108, 33.200, 33.203, 33.210 | Lopez-Soria, Luis, Ericsson | luis.lopez-soria@ece.ericsson.se | Rel-6 |  | TSG |  |  |  |
| 226 | 27.5 | Stage 3 - CN4 aspects | 334d? | 2003-05-23 A | 2004-09-01 | 85% | 50.1d? | 2003-05-23 | 2004-09-01 | 334d? | 465d | finish no earlier than 2004-09-01 | N4 | 2672h | 2271.2h | WLAN-IW | 29.234, 29.061 | Rodriguez ,Raquel, Nokia | raquel.rodriguez@nokia.com | Rel-6 |  | TSG |  |  |  |
| 227 | 27.6 | Stage 3 - CN3 aspects (Wi Interface for Scenario 3) | 355d? | 2003-05-23 A | 2004-09-30 | 95% | 17.75d? | 2003-05-23 | 2004-09-30 | 355d? | 444d | start no earlier than 2003-05-23 | N3 | 2840h | 2698h | WLAN | 29.161 |  |  | Rel-6 | SP-24 | TSG |  |  |  |
| 228 | 27.7 | Stage 3 for scenario 2 | 339d? | 2003-05-23 A | 2004-09-08 | 99% | 3.39d? | 2003-05-23 | 2004-09-08 | 339d? | 460d | finish no earlier than 2004-09-08 | N1 | 2712h | 2684.88h |  |  |  |  | Rel-6 |  | WG |  |  |  |
| 229 | 27.8 | Stage 3 for scenario 3 | 404d? | 2003-05-23 A | 2004-12-08 | 95% | 20.2d? | 2003-05-23 | 2004-09-08 | 339d? | 395d | finish no earlier than 2004-12-08 | N1 | 3232h | 3070.4h |  |  |  |  | Rel-6 | SP-24 | WG |  |  |  |
| 230 | 27.9 | WLAN charging | 580d? | 2003-03-21 A | 2005-06-09 | 90% | 58d? |  |  |  | 264d | finish no earlier than 2005-06-09 | S5 | 4640h | 4176h | WLAN-CH | 32.252 |  |  | Rel-6 |  | TSG |  |  |  |
| 231 | 33 | **Priority Service** | 666d? | 2002-05-30 A | 2004-12-16 | 78% | 146.27d? | 2002-05-30 | 2004-12-16 | 666d? | 389d |  | S1 | 12616h | 9845.13h | NTShar |  |  |  | Rel-6 |  | TSG | Michael |  |  |
| 232 | 33.1 | Feasibility Study | 1d | 2002-06-14 A | 2002-06-14 A | 100% |  | 2002-06-14 | 2002-06-14 | 1d |  | finish no earlier than 2002-06-14 | S1 | 8h | 8h | PRIOR-FS | 22.950 | Biplab K. Pramanik, Telcordia Technologies | bpramani@telcordia.com | Rel-6 |  |  | Michael |  |  |
| 233 | 33.2 | Stage 1 - Requirements | 340d | 2002-05-30 A | 2003-09-17 A | 100% |  | 2002-05-30 | 2003-09-17 | 340d |  | finish no earlier than 2003-09-17 | S1 | 2720h | 2720h | PRIOR-SR |  | James J. Garrahan, Telcordia Technologies | bpramani@telcordia.com | Rel-6 |  |  | Michael |  |  |
| 234 | 28.3 | Multimedia Priority Service | 450d? | 2003-03-28 A | 2004-12-16 | 55% | 202.5d? | 2003-03-28 | 2004-12-16 | 450d? | 389d | finish no earlier than 2004-12-16 | S1 | 3600h | 1980h |  |  |  |  | Rel-6 |  |  |  |  |  |
| 235 | 28.4 | Priority service implementation guide | 131d? | 2003-03-28 A | 2003-09-26 A | 100% |  | 2003-03-28 | 2003-09-26 | 131d? |  | finish no earlier than 2003-09-26 | S1 | 1048h | 1048h |  | 22.952 | Biplab K. Pramanik, Telcordia Technologies | bpramani@telcordia.com | Rel-6 |  |  |  |  |  |
| 236 | 34 | **Network Sharing** | 498d? | 2003-01-20 A | 2004-12-15 A | 100% |  | 2003-01-20 | 2005-03-17 | 563.41d? |  |  | S1 | 16608h | 16608h | NTShar |  |  |  | Rel-6 |  | TSG | Michael |  |  |
| 237 | 34.1 | Technical Report | 240d? | 2003-01-20 A | 2003-12-19 A | 100% |  | 2003-01-20 | 2003-12-19 | 240d? |  |  | S1 | 1920h | 1920h | NTShar-TR | 22.951 |  |  | Rel-6 |  |  | Michael |  |  |
| 238 | 29.2 | Stage 1 - CRs to implement Network Sharing | 240d? | 2003-01-20 A | 2003-12-19 A | 100% |  | 2003-01-20 | 2003-12-19 | 240d? |  | finish no earlier than 2003-12-19 | S1 | 1920h | 1920h | NTShar-CR | 22.011, 22.101, 22.115, 22.129 |  |  | Rel-6 |  |  |  |  |  |
| 239 | 29.3 | Stage 2 | 372d? | 2003-02-27 A | 2004-07-30 A | 100% |  | 2003-02-27 | 2004-07-30 | 372d? |  | finish no earlier than 2004-07-30 | S2 | 2976h | 2976h |  | 23.251 |  |  | Rel-6 |  |  |  |  |  |
| 240 | 29.4 | Network sharing - stage 3 | 404d? | 2003-05-23 A | 2004-12-08 A | 100% |  | 2003-05-23 | 2004-09-08 | 339d? |  | finish no earlier than 2004-12-08 | N1 | 3232h | 3232h |  |  |  |  | Rel-6 |  | TSG |  |  |  |
| 241 | 29.5 | Enhancement of the support of network sharing in the UTRAN | 324d | 2003-09-19 A | 2004-12-15 A | 100% |  | 2003-09-19 | 2005-03-17 | 389.41d |  | finish no earlier than 2004-12-15 | R2 | 2592h | 2592h | NTShar-UTRANEnh | TS25.401, TS25.413, TS25.331, TS25.304 | Anders Dahlén, TeliaSonera | Anders.Dahlen@TeliaSonera.com | Rel-6 |  | TSG | MCC_RAN | BB | Active |
| 242 | 35 | **QoS Improvements** | 628d? | 2002-07-15 A | 2004-12-08 | 95% | 31.06d? | 2002-07-15 | 2004-09-10 | 565d? | 395d |  | S2 | 13128h | 12478.7h | QoS1 |  |  |  | Rel-6 |  | TSG | Sang-Ui |  |  |
| 243 | 35.1 | FS on Dynamic Policy control enhancements for end-to-end QoS | 465d | 2002-07-15 A | 2004-04-23 A | 100% |  | 2002-07-15 | 2004-04-23 | 465d |  | finish no earlier than 2004-04-23 | S2 | 3720h | 3720h | QoS1 | 23.917 |  | Claire Mousset, Nortel | Rel-6 |  | TSG |  |  |  |
| 244 | 30.2 | Definition of the Gq interface | 214d? | 2003-07-01 A | 2004-04-23 A | 100% |  | 2003-07-01 | 2004-04-23 | 214d? |  | finish no earlier than 2004-04-23 | S2 | 1712h | 1712h |  | 23.221 | Janne Rinne (Nokia) |  | Rel-6 |  |  |  |  |  |
| 245 | 30.3 | Gq interface specification for Dynamic Policy control enhancements – Stage 3 | 334d | 2003-08-29 A | 2004-12-08 | 85% | 50.1d | 2003-08-29 | 2004-09-10 | 271d | 395d | finish no earlier than 2004-12-08 | N3 | 2672h | 2271.2h |  | 24,228, 29.207, 29.208 | Anna Sillanpää, Nokia | Anna.Sillanpaai@nokia.com | Rel-6 |  | TSG |  |  |  |

Notes:
- 225: Active contribution S3#24, S3#25. WID approved SA#17
- 226: WID approved at CN#19...............
- 230: Target 06/2005 completed
- 245: [DAB - 25.05.04] - Delayed to Sept - possibly Dec 2004

| ID | WBS | Task | Duration | Start | Finish | Complete | Remaining | Baseline start | Baseline finish | Baseline duration | Total slack | Constraint | Resources | Work | Actual work | Text1 | Text4 | Text5 | Text6 | Text7 | Text8 | Text10 | Text12 |
| --- | --- | --- | --- | --- | --- | --- | --- | --- | --- | --- | --- | --- | --- | --- | --- | --- | --- | --- | --- | --- | --- | --- | --- |
| 246 | 36 | **Subscriber certificates** | 728d? | 2002-02-25 A | 2004-12-08 | 93% | 50.58d? | 2002-02-25 | 2004-11-30 | 722d? | 395d |  | S3 | 12888h | 11992.5h | SEC1-SC | Valtteri Niemi, Nokia | valtteri.niemi@nokia.com | Rel-6 | TSG | Maurice |  |  |
| 247 | 36.1 | Stage 1 | 144d | 2002-02-25 A | 2002-09-12 A | 100% |  | 2002-02-25 | 2002-09-12 | 144d |  | finish no earlier than 2002-09-12 | S3 | 1152h | 1152h |  |  |  | Rel-6 |  |  |  |  |
| 248 | 36.2 | Architecture review | 24d | 2002-10-14 A | 2002-11-14 A | 100% |  | 2002-10-14 | 2002-11-14 | 24d |  | finish no earlier than 2002-11-14 | S2 | 192h | 192h |  |  |  | Rel-6 |  |  |  |  |
| 249 | 31.3 | Stage 3 | 313d? | 2003-09-19 A | 2004-11-30 | 85% | 46.95d? | 2003-09-19 | 2004-11-30 | 313d? | 401d | finish no earlier than 2004-11-30 | N4 | 2504h | 2128.4h | SEC1-SC | Lauri Laitinen, Nokia |  | Rel-6 |  | Kimmo |  |  |
| 250 | 31.4 | Stage 3 Ua & Ub interfaces | 288d? | 2003-11-03 A | 2004-12-08 | 95% | 14.4d? | 2003-11-03 | 2004-09-08 | 223d? | 395d | finish no earlier than 2004-12-08 | N1 | 2304h | 2188.8h |  |  |  | Rel-6 |  |  |  |  |
| 251 | 31.5 | OMA dependencies on Subscriber certificates | 114d? | 2004-01-01 A | 2004-06-08 A | 100% |  | 2004-01-01 | 2004-06-08 | 114d? |  | finish no earlier than 2004-06-08 | OMA | 912h | 912h |  |  | OMA-LIAISON@mail.openmobilealliance.org | Rel-6 | n/a |  | SP-24 |  |
| 252 | 32 | **Rel-6 OSA enhancements** | 616d? | 2002-10-31 A | 2005-03-10 | 82% | 110.43d? | 2002-10-31 | 2004-09-30 | 501d? | 329d |  | S1 | 27807.2h | 20140.3h | OSA3 | Chelo ABARCA (Alcatel) | Chelo.Abarca@alcatel.fr | Rel-6 | TSG | Adrian |  |  |
| 253 | 32.1 | Scope of the Open Service Access Release 6 | 66d? | 2003-03-28 A | 2003-06-27 A | 100% |  | 2003-03-28 | 2003-06-27 | 66d? |  | finish no earlier than 2003-06-27 | S1 | 528h | 528h |  |  |  | Rel-6 | TSG |  |  |  |
| 254 | 32.2 | OSA Stage 2 | 150d? | 2004-08-13 A | 2005-03-10 | 85% | 22.5d? |  |  |  | 329d | finish no earlier than 2005-03-10 | N5 | 1200h | 1020h |  |  |  | Rel-6 | TSG |  |  |  |
| 255 | 32.3 | Multi Media Messaging function | 487d? | 2002-10-31 A | 2004-09-10 A | 100% |  | 2002-10-31 | 2004-06-18 | 427d? |  | finish no earlier than 2004-09-10 | N5 | 3896h | 3896h |  |  |  | Rel-6 | TSG |  |  |  |
| 256 | 32.4 | Policy management extensions | 292d? | 2002-10-31 A | 2003-12-12 A | 100% |  | 2002-10-31 | 2003-12-12 | 292d? |  | finish no earlier than 2003-12-12 | N5 | 2336h | 2336h |  |  |  | Rel-6 | TSG |  |  |  |
| 257 | 32.5 | TS on Presence and Availability Management (from the PRESNC WI) | 367d? | 2002-10-31 A | 2004-03-26 A | 100% |  | 2002-10-31 | 2004-03-26 | 367d? |  | finish no earlier than 2004-03-26 | N5 | 2936h | 2936h |  |  |  | Rel-6 | TSG |  |  |  |
| 258 | 32.6 | OSA interfaces at different levels of abstractions (Parlay X, Web services) | 305d? | 2003-07-14 A | 2004-09-10 A | 100% |  | 2003-07-14 | 2004-06-18 | 245d? |  | finish no earlier than 2004-09-10 | N5 | 2440h | 2440h |  |  |  | Rel-6 | TSG |  |  |  |
| 259 | 32.7 | Introduction of migration support mechanism | 290d? | 2002-10-31 A | 2003-12-10 A | 100% |  | 2002-10-31 | 2003-12-10 | 290d? |  | finish no earlier than 2003-12-12 | N5 | 2320h | 2320h |  |  |  | Rel-6 | TSG |  |  |  |
| 260 | 32.8 | Framework Function for Federation | 225d? | 2003-02-03 A | 2003-12-12 A | 100% |  | 2003-02-03 | 2003-12-12 | 225d? |  | finish no earlier than 2003-12-12 | N5 | 1800h | 1800h |  |  |  | Rel-6 | TSG |  |  |  |
| 261 | 32.9 | OMA potential overlaps with 3GPP OSA Stage 3 (Web services) | 196d? | 2003-12-18 A | 2004-09-16 A | 100% |  | 2004-01-01 | 2004-09-30 | 196d? |  | start no earlier than 2003-12-18 | OMA | 1568h | 1568h |  |  |  | Rel-6 | n/a |  | SP-24 |  |
| 262 | 32.10 | Deleted - TR on Presence and Availability Management (from the PRESNC WI) | 492d? | 2002-10-31 | 2004-09-17 |  |  |  |  |  | 453d | finish no earlier than 2004-09-17 | N5 | 3936h |  |  |  |  | Rel-6 |  |  |  | NP-24 |
| 263 | 39 | **Addition of frequency bands to GSM (TAPS)** | 676d | 2002-06-28 A | 2005-01-28 | 4% | 650.96d | 2002-06-28 | 2004-11-12 | 621d | 358d |  | GP | 16640h | 616.29h | TAPS | Torben Themsen |  | Rel-6 | TSG | Paolo |  |  |
| 264 | 39.1 | **Addition of frequency bands to GSM – Changes to core specs** | 26d | 2002-11-15 A | 2002-12-20 A | 100% |  | 2002-11-15 | 2002-12-20 | 26d |  |  | G1 | 416h | 416h | TAPS-Specs | Torben Themsen |  | Rel-6 | TSG |  |  |  |
| 265 | 39.1.1 | Changes to core specs | 26d | 2002-11-15 A | 2002-12-20 A | 100% |  | 2002-11-15 | 2002-12-20 | 26d |  | finish no earlier than 2002-12-20 | G1 | 208h | 208h |  |  |  | Rel-6 |  |  |  |  |
| 266 | 39.2 | **Addition of frequency bands to GSM – Changes for conformance tests** | 676d | 2002-06-28 | 2005-01-28 |  |  | 2002-06-28 | 2004-11-12 | 621d | 358d |  | G4 | 10816h |  | TAPS-Conf | Torben Themsen |  | Rel-6 |  |  |  |  |
| 267 | 39.2.1 | 51.010-1 Add testing | 676d | 2002-06-28 | 2005-01-28 |  |  | 2002-06-28 | 2004-11-12 | 621d | 358d | finish no earlier than 2005-01-28 | G4 | 5408h |  |  |  |  | Rel-6 |  |  |  |  |
| 268 | 40 | **Seamless support of streaming services in A/Gb mode** | 1325d? | 2000-01-03 A | 2005-01-28 | 99% | 0d? | 2000-01-03 | 2004-01-30 | 1065d? | 0d |  | GP | 45728h | 42098.9h | SSStrea | José Luis Carrizo Martínez, Vodafone |  | Rel-6 | TSG | Paolo |  |  |
| 269 | 40.1 | **Identification of requirements for streaming** | 46d? | 2003-06-27 A | 2003-08-29 A | 100% |  | 2003-06-27 | 2003-08-29 | 46d? |  |  | G1 | 736h | 736h |  |  |  | Rel-6 |  |  |  |  |
| 270 | 34.1.1 | Requirements | 46d? | 2003-06-27 A | 2003-08-29 A | 100% |  | 2003-06-27 | 2003-08-29 | 46d? |  | finish no earlier than 2003-08-29 | G1 | 368h | 368h |  |  |  | Rel-6 |  |  |  |  |

Notes:
- 246: Approved at SA#14. This may require BBs from CN1, CN4, SA5 and T3 / Text3: 33.102
- 247: Contribution received S3#24, S3#25
- 249: WID approved at CN#21............
- 251: Updated according to SP-040420
- 252: CN#25: Updated WID NP-040351 replaces NP-040144. / Text3: 22.127, 23.198, 29.198, 29.199, 29.998
- 254: Task inherited by CN5 from SA2 at TSG#25. 23.127 (OSA/VHE Stage 2) to be replaced from Rel-6 onwards by a new TS 23.198 Stage 2 OSA-only in 12/04 / Text3: 23.198 OSA Stage 2-ONLY replaces 23.127 (OSA/VHE) from Rel-6 onwards
- 255: Text3: 29.198-15
- 256: Text3: 29.198, 29.998
- 257: N5#26: Split WI into TS & TR. / Text3: 29.198-14
- 258: Text3: 29.199
- 259: Text3: 29.198, 29.998
- 260: Text3: 29.198, 29.998
- 261: TSG#25 Approved CN5 29.199 Parlay X Web services. Ongoing 3GPP/OMA co-ordination to avoid OMA producing conflicting/OVERLAPING specs (NP-040283/SP-040493).
- 262: N5#26:TR Completion 09/04; consistent with CN1 delayed Rel-6 completion.
- 264: Ready
- 266: Not started
- 269: Started

| ID | WBS | Task | Duration | Start | Finish | Complete | Remaining | Baseline start | Baseline finish | Baseline duration | Total slack | Constraint | Resources | Work | Actual work | Text6 | Text3 | Text4 | Text5 | Text8 | Text1 | Text7 | Text2 |
| --- | --- | --- | --- | --- | --- | --- | --- | --- | --- | --- | --- | --- | --- | --- | --- | --- | --- | --- | --- | --- | --- | --- | --- |
| 271 | 40.2 | **Performance study of cell change mechanisms** | 955d? | 2000-01-03 A | 2003-08-29 A | 100% |  | 2000-01-03 | 2003-08-29 | 955d? |  |  | G1 | 30560h | 30560h | Rel-6 |  |  |  |  |  |  |  |
| 272 | 34.2.1 | Performance of NACC | 955d? | 2000-01-03 A | 2003-08-29 A | 100% |  | 2000-01-03 | 2003-08-29 | 955d? |  | finish no earlier than 2003-08-29 | G1 | 7640h | 7640h | Rel-6 |  |  |  |  |  |  |  |
| 273 | 34.2.2 | Performance of cell change in DTM for the PS domain | 955d? | 2000-01-03 A | 2003-08-29 A | 100% |  | 2000-01-03 | 2003-08-29 | 955d? |  | finish no earlier than 2003-08-29 | G1 | 7640h | 7640h | Rel-6 |  |  |  |  |  |  |  |
| 274 | 34.2.3 | Handover | 955d? | 2000-01-03 A | 2003-08-29 A | 100% |  | 2000-01-03 | 2003-08-29 | 955d? |  | finish no earlier than 2003-08-29 | G1 | 7640h | 7640h | Rel-6 |  |  |  |  |  |  |  |
| 275 | 40.3 | **Reduction of service interruption times and packet loss during mobility procedures** | 106d? | 2003-06-27 A | 2003-11-21 | 99% | 0d? | 2003-06-27 | 2003-11-21 | 106d? | 0d |  | G2 | 4240h | 3396h | Rel-6 |  |  |  |  |  |  |  |
| 276 | 34.3.1 | Optimisations of existing mechanisms/procedures | 106d? | 2003-06-27 A | 2003-11-21 A | 100% |  | 2003-06-27 | 2003-11-21 | 106d? |  | finish no earlier than 2003-11-21 | G2 | 848h | 848h | Rel-6 |  |  |  |  |  |  |  |
| 277 | 34.3.2 | Inter-system NACC | 106d? | 2003-06-27 A | 2003-11-21 A | 100% |  | 2003-06-27 | 2003-11-21 | 106d? |  | finish no earlier than 2003-11-21 | G2 | 848h | 848h | Rel-6 |  |  |  |  |  |  |  |
| 278 | 34.3.3 | PS Handover (within GERAN and between GERAN and UTRAN) | 106d? | 2003-06-27 A | 2003-11-21 A | 100% |  | 2003-06-27 | 2003-11-21 | 106d? |  | finish no earlier than 2003-11-21 | G2 | 848h | 848h | Rel-6 |  |  |  |  |  |  |  |
| 279 | 34.3.4 | Dependency to other features | 106d? | 2003-06-27 A | 2003-11-21 A | 100% |  | 2003-06-27 | 2003-11-21 | 106d? |  | finish no earlier than 2003-11-21 | G2 | 848h | 848h | Rel-6 |  |  |  |  |  |  |  |
| 280 | 40.5 | **MS conformance testing** | 31d? | 2003-12-19 A | 2004-01-30 A | 100% |  | 2003-12-19 | 2004-01-30 | 31d? |  |  | G3 | 248h | 248h | Rel-6 |  |  |  |  |  |  |  |
| 281 | 34.4.1 | MS conformance tests | 31d? | 2003-12-19 A | 2004-01-30 A | 100% |  | 2003-12-19 | 2004-01-30 | 31d? |  | finish no earlier than 2004-01-30 | G4,G5 | 248h | 248h | Rel-6 |  |  |  |  |  |  |  |
| 282 | 34.5 | GERAN A/Gb mode security enhancements | 612d? | 2002-09-26 A | 2005-01-28 A | 100% |  | 2002-09-26 | 2003-09-25 | 261d? |  | finish no earlier than 2005-01-28 | S3 | 4896h | 4896h | Rel-6 | 33.102 | Peter Howard, Vodafone | peter.howard@vodafone.com | Maurice |  |  |  |
| 283 | 41 | Performance characterisation of default codecs for PS conversational multimedia application | 455d | 2002-09-13 A | 2004-06-10 A | 100% |  | 2002-09-13 | 2004-06-10 | 455d |  | finish no earlier than 2004-06-10 | S4 | 3640h | 3640h | Rel-6 | TR 26.935 | Pasi Ojala (Nokia) | pasi.s.ojala@nokia.com | Paolo | CODCAR | TSG |  |
| 284 | 43 | Study on Privacy Capability | 83d | 2003-11-10 A | 2004-03-03 | 85% | 12.45d | 2003-11-10 | 2004-03-03 | 83d | 595d | start no earlier than 2003-11-10 | S1 | 664h | 564.4h | Rel-6 | TR 21.xyz | Liz Daniel, Lucent |  | Michael | PrivCap | TSG |  |
| 285 | 44 | **OAM&P** | 715d? | 2002-09-12 A | 2005-06-08 | 87% | 95.48d? | 2002-09-12 | 2004-12-08 | 585d? | 265d |  | S5 | 34083.5h | 24517.4h |  | 32-series | Michael TRUSS (Motorola) | Michael.Truss@MOTOROLA.COM | Adrian | OAM | TSG |  |
| 286 | 44.1 | Principles, high level Requirements and Architecture | 526d | 2002-09-12 A | 2004-09-16 A | 100% |  | 2002-09-12 | 2004-09-16 | 526d |  | finish no earlier than 2004-09-16 | S5 | 4208h | 4208h | Rel-6 | 32.101, 32.102 | Michael TRUSS (Motorola) | Michael.Truss@MOTOROLA.COM |  | OAM-AR | TSG | BCaM |
| 287 | 44.2 | Performance Management | 591d | 2002-09-12 A | 2004-12-16 A | 100% |  | 2002-09-12 | 2004-09-16 | 526d |  | finish no earlier than 2004-12-16 | S5 | 4728h | 4728h | Rel-6 | 32.401/3, 52.402, 32.411/2/3, 32.432/5/6 | Christian TOCHE (Nortel Networks) | toche@NORTELNETWORKS.COM |  | OAM-PM | TSG | BCaM |
| 288 | 44.4 | Network Infrastructure Management | 591d | 2002-09-12 A | 2004-12-16 A | 100% |  | 2002-09-12 | 2004-09-16 | 526d |  | finish no earlier than 2004-12-16 | S5 | 4728h | 4728h | Rel-6 | 32.15x, 32.3/6/7xy | Thomas TOVINGER (Ericsson) | Thomas.Tovinger@emw.ericsson.se |  | OAM-NIM | TSG |  |
| 289 | 44.5 | **Trace Management** | 709d? | 2002-09-20 A | 2005-06-08 | 69% | 216.38d? | 2002-09-20 | 2004-12-08 | 579d? | 265d |  | S5 | 14821.9h | 7781.05h |  | 32.42x, 52.008 | Kari RÖNKÄ (Nokia) | kari.t.ronka@nokia.com |  | OAM-Trace | TSG |  |
| 290 | 37.4.1 | Subscriber and UE trace management | 585d | 2002-09-20 A | 2004-12-16 A | 100% |  | 2002-09-20 | 2004-09-16 | 520d |  | finish no earlier than 2004-12-16 | S5 | 4680h | 4680h | Rel-6 | 32.421/2/3, 52.008 | Kari RÖNKÄ (Nokia) | kari.t.ronka@nokia.com |  | OAM-Trace | TSG |  |
| 291 | 37.4.2 | Subscriber and equipment trace in UTRAN | 268d? | 2003-06-06 A | 2004-06-15 A | 100% |  | 2003-06-06 | 2004-06-15 | 268d? |  | finish no earlier than 2004-06-15 | R3 | 2144h | 2144h | Rel-6 | TS25.413, 25.420, 25.423 | Yann Sehedi, Nortel | sehedic@nortelnetworks.com | MCC_RAN | OAM-Trace-RAN | TSG |  |
| 292 | 37.4.3 | SIP enhancements for trace | 343d? | 2004-02-16 A | 2005-06-08 | 2% | 336.14d? | 2004-02-16 | 2004-12-08 | 213d? | 265d | finish no earlier than 2005-06-08 | N1 | 2744h | 54.88h | Rel-7 |  |  |  |  | Trace-SIP |  |  |
| 293 | 37.4.4 | Trace Management, Stage3 | 132.74d? | 2004-06-09 A | 2004-12-16 | 48% | 69.37d? | 2004-02-16 | 2004-12-08 | 213d? | 389d | finish no earlier than 2004-12-16 | N4 | 1061.93h | 506.97h |  | TS 23.205, 29.232, 29.060, 29.002, 29.228 | Seppo Kauntola ( Nokia Corporation) | seppo.kauntola@nokia.com |  | OAM-Trace |  |  |
| 294 | 38 | **Charging Management** | 666d? | 2002-11-21 A | 2005-06-09 | 92% | 55.08d? | 2002-11-21 | 2004-09-16 | 476d? | 264d |  | S5 | 54248h | 44796.9h | Rel-6 | 32.2xy | Karl-Heinz NENNER (T-Mobile) | karl-heinz.nenner@t-mobile.de | Adrian | CH | TSG |  |
| 295 | 38.1 | Charging architecture and principles | 390d? | 2003-03-21 A | 2004-09-16 A | 100% |  |  |  |  |  | start no earlier than 2003-03-21 | S5 | 3120h | 3120h | Rel-6 | 32.240 |  |  |  | CH | TSG |  |
| 296 | 38.2 | Charging Data Record (CDR) file format and transfer | 260d? | 2003-03-21 A | 2004-03-18 A | 100% |  |  |  |  |  | start no earlier than 2003-03-21 | S5 | 2080h | 2080h | Rel-6 | 32.297 |  |  |  | CH | TSG |  |
| 297 | 38.3 | CDR parameter description | 580d? | 2003-03-21 A | 2005-06-09 | 90% | 58d? |  |  |  | 264d | finish no earlier than 2005-06-09 | S5 | 4640h | 4176h | Rel-6 | 32.298 |  |  |  | CH | TSG |  |
| 298 | 38.4 | Diameter charging applications | 390d? | 2003-03-21 A | 2004-09-16 A | 100% |  |  |  |  |  | start no earlier than 2003-03-21 | S5 | 3120h | 3120h | Rel-6 | 32.299 |  |  |  | CH | TSG |  |
| 299 | 38.5 | Online Charging System (OCS) architecture study | 130d? | 2003-03-21 A | 2003-09-18 A | 100% |  |  |  |  |  | start no earlier than 2003-03-21 | S5 | 1040h | 1040h | Rel-6 | 32.815 |  |  |  | CH | TSG |  |
| 300 | 38.6 | OCS: Applications and interfaces | 455d? | 2003-03-21 A | 2004-12-16 A | 100% |  |  |  |  |  | start no earlier than 2003-03-21 | S5 | 3640h | 3640h | Rel-6 | 32.296 |  |  |  | CH | TSG |  |

Notes:
- 271: Started
- 275: Completed at GERAN#17
- 280: Closed, no work needed
- 281: Closed, no work needed
- 282: Possible changes to 33.102 or new specification needed.
- 285: SA#26: Updated WID SP-040766 was SP-020445. Completion delayed 12/04->03/05 due to OAM-Trace in CN1/4.
- 286: SA#26: Updated WID SP-040767 was SP-020446
- 287: SA#26: Updated WID SP-040782 was SP-020499
- 288: SA#26: Updated WID SP-040789 was SP-020754
- 289: TSG#26: SA#26: Updated WID SP-040782 was SP-020499. SA5 completed 12/04. Signalling Based Trace Activation for IMS (SIP) moved to Rel-7. Reason: CN1 cannot complete 24.229 trace without IETF dependency => estimate 05/2005.
- 290: TSG#26: Approved 32.423/52.008. SA5 work completed 12/2004.
- 294: SA#26: Updated WID SP-040773 was SP-030047. Target 06/2005 for WLAN/PoC/MBMS Charging 32.252/72/73/98
- 295: SA#25 09/2004 completed
- 296: SA#23 03/2004 completed
- 297: Target SA#27 03/2005 completed
- 298: SA#25 09/2004 completed
- 299: SA#21 09/2003 completed
- 300: SA#26 12/2004 completed

| ID | WBS | Task | Duration | Start | Finish | Complete | Remaining | Baseline start | Baseline finish | Baseline duration | Total slack | Constraint | Resources | Work | Actual work | Text1 | Text4 | Text6 | Text7 | Text10 | Text5 | Text2 | Text8 | Text9 |
| --- | --- | --- | --- | --- | --- | --- | --- | --- | --- | --- | --- | --- | --- | --- | --- | --- | --- | --- | --- | --- | --- | --- | --- | --- |
| 301 | 38.7 | **Charging Management for Bearer level** | 390d? | 2003-03-21 A | 2004-09-16 A | 100% |  | 2003-03-21 | 2004-09-16 | 390d? |  |  | S5 | 11440h | 11440h | CH-BC | Benni ALEXANDER (Nokia) | Rel-6 | TSG |  |  |  |  |  |
| 302 | 38.7.1 | CS domain charging | 260d? | 2003-03-21 A | 2004-03-18 A | 100% |  |  |  |  |  | start no earlier than 2003-03-21 | S5 | 2080h | 2080h | CH |  | Rel-6 | TSG |  |  |  |  |  |
| 303 | 38.7.2 | PS domain charging | 390d? | 2003-03-21 A | 2004-09-16 A | 100% |  |  |  |  |  | start no earlier than 2003-03-21 | S5 | 3120h | 3120h | CH |  | Rel-6 | TSG |  |  |  |  |  |
| 304 | 38.7.3 | CDR transfer | 390d? | 2003-03-21 A | 2004-09-16 A | 100% |  |  |  |  |  | start no earlier than 2003-03-21 | S5 | 3120h | 3120h | CH |  | Rel-6 | TSG |  |  |  |  |  |
| 305 | 38.8 | Charging Management for the IMS | 455d? | 2003-03-21 A | 2004-12-16 A | 100% |  | 2003-03-21 | 2004-09-16 | 390d? |  | finish no earlier than 2004-12-16 | S5 | 3640h | 3640h | IMS2-CH | Patrik TEPPO (Ericsson) | Rel-6 | TSG |  |  |  |  |  |
| 306 | 38.9 | Charging Management for the Service domain | 580d? | 2003-03-21 A | 2005-06-09 | 90% | 58d? | 2003-03-21 | 2004-09-16 | 390d? | 264d | finish no earlier than 2005-06-09 | S5 | 4640h | 4176h | CH | Gerald GÖRMER (Siemens) | Rel-6 | TSG |  |  |  |  |  |
| 307 | 38.10 | **Overall architectural aspects of IP flow based bearer level charging** | 535d? | 2002-11-21 A | 2004-12-08 | 66% | 184.13d? | 2002-11-21 | 2004-07-30 | 442d? | 395d |  | S2 | 11560h | 6751.68h | CH-FBC |  | Rel-6 |  |  |  |  |  |  |
| 308 | 38.10.1 | Overall definition of FBC architecture | 334d? | 2002-11-21 A | 2004-03-02 | 99% | 1d? | 2002-11-21 | 2004-03-02 | 334d? | 596d | start no earlier than 2002-11-21 | S2 | 2672h | 2664h |  |  | Rel-6 |  | SP-24 |  |  |  |  |
| 309 | 38.10.2 | Study on providing policy control with FBC | 130d? | 2004-02-02 A | 2004-07-30 A | 100% |  | 2004-02-02 | 2004-07-30 | 130d? |  | start no earlier than 2004-02-01 | S2 | 1040h | 1040h |  |  | Rel-6 |  | SP-24 |  |  |  |  |
| 310 | 38.10.3 | Gx interface for flow based charging | 223d? | 2004-02-02 A | 2004-12-08 | 50% | 111.5d? | 2004-02-02 | 2004-07-30 | 130d? | 395d | start no earlier than 2004-02-01 | N3 | 1784h | 892h |  |  | Rel-6 |  | SP-25 |  |  |  |  |
| 311 | 38.10.4 | Rx interface for flow based charging | 223d? | 2004-02-02 A | 2004-12-08 | 10% | 200.7d? | 2004-02-02 | 2004-07-30 | 130d? | 395d | start no earlier than 2004-02-01 | N3 | 1784h | 178.4h |  | Javier Gonzalez Gallego | Rel-6 |  | SP-25 | ggfj@nortelnetworks.com |  |  |  |
| 312 | 13 | **Rel-6 UICC/USIM enhancements and interworking** | 1164d | 2000-09-25 A | 2005-03-10 | 74% | 300.39d | 2000-09-25 | 2004-02-19 | 889d | 329d |  | T3 | 35312h | 27307.3h | USAT1 |  | Rel-6 | TSG |  |  | Ter | Claus | 1800 |
| 313 | 13.1 | **UICC API** | 777d | 2002-03-20 A | 2005-03-10 | 57% | 332.97d | 2002-03-20 | 2004-02-19 | 502d | 329d |  | T3 | 14936h | 8535.44h | USAT1-API |  | Rel-6 |  |  |  | Ter |  | 1802 |
| 314 | 13.1.1 | Java API Test specification | 59d | 2002-03-20 A | 2002-06-10 A | 100% |  | 2002-03-20 | 2002-06-10 | 59d |  | finish no earlier than 2002-09-20 | T3 | 472h | 472h |  | Mario Pérez (Microelectrónica Española) | Rel-6 |  |  |  |  |  |  |
| 315 | 13.1.2 | Java API Test specification (TS 43.019 Rel-5) | 268d | 2002-05-30 A | 2003-06-09 A | 100% |  | 2002-05-30 | 2003-06-09 | 268d |  | finish no earlier than 2003-09-17 | T3 | 2144h | 2144h |  | Mario Pérez (Microelectrónica Española) | Rel-6 |  |  |  |  |  |  |
| 316 | 39.1.3 | 2G/3G Java Card™ API based applet interworking | 244d | 2003-03-17 A | 2004-02-19 A | 100% |  | 2003-03-17 | 2004-02-19 | 244d |  | finish no earlier than 2004-02-19 | T3 | 1952h | 1952h | USAT1-API | Stéphane Andrau-Oberthur Card Systems | Rel-6 | TSG |  |  |  |  |  |
| 317 | 39.1.4 | (U)SIM API for Java Card Testing Work Item | 519d | 2003-03-17 A | 2005-03-10 | 10% | 467.1d | 2003-03-17 | 2004-02-19 | 244d | 329d | finish no earlier than 2005-03-10 | T3 | 4152h | 415.2h |  | Christophe Begassat (Axalto) | Rel-6 | TSG |  | 'cbegassat@axalto.com' |  | Friedhelm |  |
| 318 | 39.2 | **Rel-6 USIM toolkit enhancements** | 525d | 2000-09-25 A | 2002-09-27 A | 100% |  | 2000-09-25 | 2002-09-27 | 525d |  |  | T3 | 14160h | 14160h |  |  | Rel-6 |  |  |  |  | Claus |  |
| 319 | 39.2.1 | **C SIM API** | 525d | 2000-09-25 A | 2002-09-27 A | 100% |  | 2000-09-25 | 2002-09-27 | 525d |  |  | T3 | 9960h | 9960h | USAT1-API-MULTOS |  | Rel-6 | TSG |  |  | Ter |  | 2031 |
| 320 | 39.2.1.1 | Specification | 525d | 2000-09-25 A | 2002-09-27 A | 100% |  | 2000-09-25 | 2002-09-27 | 525d |  | finish no earlier than 2002-09-27 | T3 | 4200h | 4200h |  | Neil Livingston – Aspects Software | Rel-6 | TSG |  |  | Ter |  | 2032 |
| 321 | 39.2.1.2 | Test specification | 195d | 2001-01-01 A | 2001-09-28 A | 100% |  | 2001-01-01 | 2001-09-28 | 195d |  | finish no earlier than 2001-09-28 | T3 | 1560h | 1560h |  | Neil Livingston – Aspects Software | Rel-6 | TSG |  |  | Ter |  | 2033 |
| 322 | 40 | **Packet Switched Streaming Services Rel-6** | 609d? | 2002-11-18 A | 2005-03-17 | 96% | 26.58d? | 2002-11-18 | 2004-09-16 | 479d? | 324d |  | S4 | 10280h | 9831.39h | PSSrel6 | Olle Franceschi (Ericsson) | Rel-6 | TSG |  | olle.franceschi@ericsson.com |  | Paolo |  |
| 323 | 40.1 | Stage 1 | 86d? | 2002-11-18 A | 2003-03-17 A | 100% |  | 2002-11-18 | 2003-03-17 | 86d? |  | finish no earlier than 2003-03-17 | S1 | 688h | 688h |  |  | Rel-6 | TSG |  |  |  |  |  |
| 324 | 40.2 | Stage 3 | 590d? | 2002-12-13 A | 2005-03-17 | 95% | 29.5d? | 2002-12-13 | 2004-09-16 | 460d? | 324d | finish no earlier than 2005-03-17 | S4 | 4720h | 4484h | PSSrel6-Stage3 | Olle Franceschi (Ericsson) | Rel-6 | WG |  | olle.franceschi@ericsson.com |  | Paolo |  |
| 325 | 41 | AMR-WB extension for high audio quality | 590d | 2002-12-13 A | 2005-03-17 | 95% | 29.5d | 2002-12-13 | 2004-06-10 | 390d | 324d | finish no earlier than 2005-03-17 | S4 | 4720h | 4484h | AMRWB+ | Janne Vainio (Nokia) | Rel-6 | TSG |  | janne.m.vainio@nokia.com |  | Paolo |  |
| 326 | 42 | Codec Enhancements for Packet Switched Conversational Multimedia Applications | 198d? | 2004-03-16 A | 2004-12-16 A | 100% |  | 2004-03-16 | 2004-09-16 | 133d? |  | finish no earlier than 2004-12-16 | S4 | 1584h | 1584h | CEPSCM | Miska Hannuksela (Nokia) | Rel-6 | WG |  | miska.hannuksela@nokia.com |  | Paolo |  |
| 327 | 43 | 3G-324M Improvements | 198d? | 2004-03-16 A | 2004-12-16 A | 100% |  | 2004-03-16 | 2004-09-16 | 133d? |  | finish no earlier than 2004-12-16 | S4 | 1584h | 1584h | 3G-324MI | Bo Burman, Ericsson | Rel-6 | WG |  | bo.burman@ericsson.com |  | Paolo |  |
| 328 | 44 | Single Antenna Receiver Interference Cancellation (SAIC) | 420.92d? | 2002-11-15 A | 2004-08-27 A | 100% |  | 2002-11-15 | 2004-06-25 | 375.92d? |  | finish no earlier than 2004-08-27 | GP; G1 | 6734.72h | 6734.72h | SAIC | Marc Grant, Cingular Wireless | Rel-6 | TSG |  |  |  | Paolo |  |

Notes:
- 302: SA#23 03/2004 completed / Text3: 32.250
- 303: SA#25 09/2004 completed / Text3: 32.251
- 304: SA#25 09/2004 completed / Text3: 32.295
- 305: SA#26 12/2004 completed / Text3: 32.260
- 306: SA#26: Updated WID SP-040778 was SP-030050. Target completion 06/2005. Consisting of MMS-CH, LCS-CH, WLAN-CH, POC-CH, MBMS-CH / Text3: 32.252, 32.270/1/2
- 307: Text3: 23.125
- 310: Text3: 29.210
- 311: Text3: 29.209
- 313: 8/3/2001: test spec is based on R99 core spec, so deleted from Workplan
- 317: Text3: 31.213
- 323: 2nd resp SA4 / Text3: 22.233
- 324: Text3: 26.233, 26.234, 26.244, 26.245, 26.246, 26.401, 26.402, 26.403, 26.404, 26.405, 26.410, 26.411, 26.273, 26.290, 26.304
- 325: Text3: 26.290, 26.304, 26.273
- 326: Completed / Text3: 26.235, 26.236
- 327: Completed / Text3: 26.111, 26.911

| ID | WBS | Task | Duration | Start | Finish | Complete | Remaining | Baseline start | Baseline finish | Baseline duration | Total slack | Constraint | Resources | Work | Actual work | Text1 | Text4 | Text5 | Text6 | Text7 | Text8 | Text3 |
| --- | --- | --- | --- | --- | --- | --- | --- | --- | --- | --- | --- | --- | --- | --- | --- | --- | --- | --- | --- | --- | --- | --- |
| 329 | 45 | **Support of Conversational Services in A/Gb mode via the PS domain** | 721d? | 2003-02-07 A | 2005-11-11 | 25% | 542.3d? | 2003-02-07 | 2004-08-27 | 406d? | 153d |  | GP | 30392h | 4322.93h | SCSAGB | David Bladsjö, Ericsson | david.bladsjo@ericsson.com | Rel-6 | TSG | Paolo |  |
| 330 | 45.1 | Creation of a TR | 206d? | 2003-02-07 A | 2003-11-21 A | 100% |  | 2003-02-07 | 2003-11-21 | 206d? |  | finish no earlier than 2003-11-21 | GP | 1648h | 1648h | SCSAGB-TR | David Bladsjö, Ericsson |  | Rel-6 | TSG |  |  |
| 331 | 45.2 | Stage 2 | 311d? | 2003-11-21 A | 2005-01-28 | 85% | 46.65d? | 2003-11-21 | 2004-08-27 | 201d? | 358d | finish no earlier than 2005-01-28 | GP | 2488h | 2114.8h | SCSAGB-Stage2 | David Bladsjö, Ericsson |  | Rel-6 | TSG |  |  |
| 332 | 45.3 | Radio Channel Support | 461d? | 2004-02-06 | 2005-11-11 |  |  | 2004-02-06 | 2004-08-27 | 146d? | 153d | finish no earlier than 2005-11-11 | GP | 3688h |  | SCSAGB-RCS | David Bladsjö, Ericsson |  | Rel-6 | TSG |  |  |
| 333 | 45.4 | Definition of radio resource management functionality | 461d? | 2004-02-06 | 2005-11-11 |  |  | 2004-02-06 | 2004-08-27 | 146d? | 153d | finish no earlier than 2005-11-11 | GP; G2 | 7376h |  | SCSAGB-RRM | David Bladsjö, Ericsson |  | Rel-6 | TSG |  |  |
| 334 | 45.5 | PS Handover | 256d? | 2004-02-06 A | 2005-01-28 | 25% | 192d? | 2004-02-06 | 2004-08-27 | 146d? | 358d | finish no earlier than 2005-01-28 | GP | 2048h | 512h | SCSAGB-PSH | David Bladsjö, Ericsson |  | Rel-6 | TSG |  |  |
| 335 | 45.6 | Modifications to FLO | 461d? | 2004-02-06 | 2005-11-11 |  |  | 2004-02-06 | 2004-08-27 | 146d? | 153d | finish no earlier than 2005-11-11 | GP; G2 | 7376h |  | SCSAGB-FLO | David Bladsjö, Ericsson |  | Rel-6 | TSG |  |  |
| 336 | 46 | **Enhancement of dialled service for CAMEL** | 199d | 2003-03-28 A | 2003-12-31 A | 100% |  | 2003-03-28 | 2003-12-31 | 199d |  |  | S1 | 3184h | 3184h | EDCAMEL | Craig Bishop, Samsung Electronics Research Institute |  | Rel-6 | TSG | Andrijana |  |
| 337 | 46.1 | Stages 2 and 3 | 199d | 2003-03-28 A | 2003-12-31 A | 100% |  | 2003-03-28 | 2003-12-31 | 199d |  | finish no earlier than 2003-09-19 | N4 | 1592h | 1592h |  |  |  | Rel-6 |  |  |  |
| 338 | 47 | Bandwidth and resource savings in CS networks | 273d? | 2003-06-01 A | 2004-06-16 A | 100% |  | 2003-06-01 | 2004-06-16 | 273d? |  | finish no earlier than 2004-06-16 | S2 | 2184h | 2184h | BARS |  |  | Rel-6 |  | Sang-Ui | 23.977 |
| 339 | 48 | FS on (U)SIM Security Reuse by Peripheral Devices on Local Interfaces | 127d? | 2003-07-03 A | 2003-12-26 A | 100% |  | 2003-07-03 | 2003-12-26 | 127d? |  | finish no earlier than 2003-12-26 | S3 | 1016h | 1016h |  | Raziq Yaqub, Toshiba America Research Inc. | ryaqub@tari.toshiba.com | Rel-6 | TSG | Maurice |  |
| 340 | 49 | **Multiple TBF in A/Gb mode** | 736d? | 2002-04-05 A | 2005-01-28 | 60% | 295.36d? | 2002-04-05 | 2004-06-25 | 581d? | 358d |  | GP; G2 | 41088h | 27408.6h | MULTBF | Gunnar Mildh, Ericsson |  | Rel-6 | TSG | Paolo |  |
| 341 | 49.1 | **Multiple TBF in A/Gb mode** | 366d? | 2002-04-05 A | 2003-08-29 A | 100% |  | 2002-04-05 | 2003-08-29 | 366d? |  |  | GP; G2 | 23424h | 23424h | MULTBF-Agbmode | Gunnar Mildh, Ericsson |  | Rel-6 | TSG |  |  |
| 342 | 49.1.1 | Multiple TBF Concept paper | 366d? | 2002-04-05 A | 2003-08-29 A | 100% |  | 2002-04-05 | 2003-08-29 | 366d? |  | finish no earlier than 2003-08-29 | GP; G2 | 5856h | 5856h |  |  |  | Rel-6 |  |  |  |
| 343 | 49.1.2 | Multiple TBF Stage 2 (43.064) CRs | 366d? | 2002-04-05 A | 2003-08-29 A | 100% |  | 2002-04-05 | 2003-08-29 | 366d? |  | finish no earlier than 2003-08-29 | GP; G2 | 5856h | 5856h |  |  |  | Rel-6 |  |  |  |
| 344 | 49.1.3 | Multiple TBF Stage 3 (44.060) CRs | 366d? | 2002-04-05 A | 2003-08-29 A | 100% |  | 2002-04-05 | 2003-08-29 | 366d? |  | finish no earlier than 2003-08-29 | GP; G2 | 5856h | 5856h |  |  |  | Rel-6 |  |  |  |
| 345 | 49.2 | Multiple TBF in A/Gb mode – MS testing | 736d? | 2002-04-05 | 2005-01-28 |  |  | 2002-04-05 | 2004-06-25 | 581d? | 358d | finish no earlier than 2005-01-28 | G3 | 5888h |  | MULTBF-Testing | Gunnar Mildh, Ericsson |  | Rel-6 | TSG | Paolo |  |
| 346 | 50 | **Alignment between the test-regimes for GERAN capable MS** | 371d? | 2003-08-29 A | 2005-01-28 | 80% | 74.2d? | 2003-08-29 | 2004-08-27 | 261d? | 358d |  | G3 | 5936h | 2374.4h | ALTERE | Toubassi, Ericsson |  | Rel-6 | TSG | Michael |  |
| 347 | 50.1 | Determine the controversial test cases in the different test regimes and align them with 3GPP GERAN test specifications. Such test cases to be added to TS 51.010. | 371d? | 2003-08-29 A | 2005-01-28 | 80% | 74.2d? | 2003-08-29 | 2004-08-27 | 261d? | 358d | finish no earlier than 2005-01-28 | G3 | 2968h | 2374.4h | ALTERE-TC |  |  | Rel-6 | TSG |  |  |
| 348 | 51 | Addition of U-TDOA in the CS domain | 111d? | 2003-11-21 A | 2004-04-23 A | 100% |  | 2003-11-21 | 2004-04-23 | 111d? |  | finish no earlier than 2004-04-23 | GP | 888h | 888h | UTDOACS | Bob Gross, Rhys Robinson, TruePosition, Inc. | rlgross@trueposition.com | Rel-6 | TSG | Paolo |  |
| 349 | 52 | Addition of U-TDOA in the PS domain | 361d? | 2003-06-27 A | 2004-11-12 A | 100% |  | 2003-06-27 | 2004-11-12 | 361d? |  | finish no earlier than 2004-11-12 | GP | 2888h | 2888h | UTDOAPS | Bob Gross, Rhys Robinson, TruePosition, Inc. | rlgross@trueposition.com | Rel-6 | TSG | Paolo |  |
| 350 | 53 | **Downlink Advanced Receiver Performance** | 332d? | 2003-11-21 A | 2005-02-28 | 92% | 25.17d? | 2003-11-21 | 2005-02-28 | 332d? | 337d |  | GP | 17016h | 10332.5h | DARP | Tommy Bysted, Nokia | tommy.bysted@nokia.com | Rel-6 | TSG | Paolo |  |
| 351 | 53.1 | DARP test scenarios | 201d? | 2003-11-21 A | 2004-08-27 A | 100% |  | 2003-11-21 | 2004-08-27 | 201d? |  | finish no earlier than 2004-08-27 | GP | 1608h | 1608h | DARP-TS | Tommy Bysted, Nokia | tommy.bysted@nokia.com | Rel-6 | TSG | Paolo |  |
| 352 | 53.2 | **DARP for GMSK modulated voice services** | 201d? | 2004-02-06 A | 2004-11-12 | 99% | 0d? | 2004-02-06 | 2004-11-12 | 201d? | 0d |  | GP | 4824h | 3216h | DARP-GMSK | Tommy Bysted, Nokia | tommy.bysted@nokia.com | Rel-6 | TSG | Paolo |  |
| 353 | 53.2.1 | Performance requirements in 45.005 | 201d? | 2004-02-06 A | 2004-11-12 A | 100% |  | 2004-02-06 | 2004-11-12 | 201d? |  | finish no earlier than 2004-11-12 | GP | 1608h | 1608h | DARP-GMSK-Perf |  |  | Rel-6 | TSG |  |  |
| 354 | 53.2.2 | Radio subsystem link control in 45.008 | 201d? | 2004-02-06 A | 2004-11-12 A | 100% |  | 2004-02-06 | 2004-11-12 | 201d? |  | finish no earlier than 2004-11-12 | GP | 1608h | 1608h | DARP-GMSK-LC |  |  | Rel-6 | TSG |  |  |

Notes:
- 331: Started
- 332: Not started
- 333: Not started
- 334: Started
- 335: Not started
- 339: Approved TSG#20
- 345: Under evaluation
- 347: Started
- 348: Completed, except for potential LMU performance specs

| ID | WBS | Task | Duration | Start | Finish | Complete | Remaining | Baseline start | Baseline finish | Baseline duration | Total slack | Constraint | Resources | Work | Actual work | Text1 | Text4 | Text5 | Text6 | Text7 | Text8 | Text3 | Text10 | Text9 |
| --- | --- | --- | --- | --- | --- | --- | --- | --- | --- | --- | --- | --- | --- | --- | --- | --- | --- | --- | --- | --- | --- | --- | --- | --- |
| 355 | 53.3 | **DARP for GPRS and EGPRS MCS1-MCS4** | 201d? | 2004-02-06 A | 2004-11-12 | 99% | 0d? | 2004-02-06 | 2004-11-12 | 201d? | 0d |  | GP | 4824h | 3216h | DARP-GPRSE | Tommy Bysted, Nokia | tommy.bysted@nokia.com | Rel-6 | TSG | Paolo |  |  |  |
| 356 | 53.3.1 | Performance requirements in 45.005 | 201d? | 2004-02-06 A | 2004-11-12 A | 100% |  | 2004-02-06 | 2004-11-12 | 201d? |  | finish no earlier than 2004-11-12 | GP | 1608h | 1608h | DARP-GPRSE-Perf |  |  | Rel-6 | TSG |  |  |  |  |
| 357 | 53.3.2 | Radio subsystem link control in 45.008 | 201d? | 2004-02-06 A | 2004-11-12 A | 100% |  | 2004-02-06 | 2004-11-12 | 201d? |  | finish no earlier than 2004-11-12 | GP | 1608h | 1608h | DARP-GPRSE-LC |  |  | Rel-6 | TSG |  |  |  |  |
| 358 | 53.4 | DARP Capability signalling | 256d? | 2003-11-21 A | 2004-11-12 A | 100% |  | 2003-11-21 | 2004-06-25 | 156d? |  | finish no earlier than 2004-11-12 | GP | 2048h | 2048h | DARP-CAPSIG | Tommy Bysted, Nokia | tommy.bysted@nokia.com | Rel-6 | TSG | Paolo |  |  |  |
| 359 | 53.5 | GERAN MS Conformance test for DARP | 132d? | 2004-08-27 A | 2005-02-28 | 20% | 105.6d? | 2004-08-27 | 2005-02-28 | 132d? | 337d | finish no earlier than 2005-02-28 | G3 | 1056h | 211.2h | ARP-ConfTest | Tommy Bysted, Nokia | tommy.bysted@nokia.com | Rel-6 | TSG | Michael |  |  |  |
| 360 | 54 | **Reduction of PS service interruption in Dual Transfer Mode** | 311d? | 2003-11-21 A | 2005-01-28 | 54% | 142.69d? | 2003-11-21 | 2004-11-12 | 256d? | 358d |  | G2 | 7928h | 2968.18h | PSintDTM | Toby Proctor, Siemens | toby.proctor@roke.co.uk | Rel-6 | TSG | Gert |  |  |  |
| 361 | 54.1 | Use case and requirement definition | 111d? | 2003-11-21 A | 2004-04-23 A | 100% |  | 2003-11-21 | 2004-04-23 | 111d? |  | finish no earlier than 2004-04-23 | G2 | 888h | 888h | PSintDTM-Req | Toby Proctor, Siemens | toby.proctor@roke.co.uk | Rel-6 | TSG | Gert |  |  |  |
| 362 | 54.2 | Performance Study of Current Procedures | 111d? | 2003-11-21 A | 2004-04-23 A | 100% |  | 2003-11-21 | 2004-04-23 | 111d? |  | start no earlier than 2003-11-21 | G2 | 888h | 888h | PSintDTM-Perf | Toby Proctor, Siemens | toby.proctor@roke.co.uk | Rel-6 | TSG | Gert |  |  |  |
| 363 | 54.3 | Reduction of service interruption times and packet loss during Dual Transfer Mode and mobility procedures | 146d? | 2004-04-23 A | 2004-11-12 A | 100% |  | 2004-04-23 | 2004-06-25 | 46d? |  | finish no earlier than 2004-11-12 | G2 | 1168h | 1168h | PSintDTM-Reduct | Toby Proctor, Siemens | toby.proctor@roke.co.uk | Rel-6 | TSG | Gert |  |  |  |
| 364 | 54.4 | MS Conformance testing | 156d? | 2004-06-25 | 2005-01-28 |  |  | 2004-06-25 | 2004-11-12 | 101d? | 358d | finish no earlier than 2005-01-28 | G3 | 1248h |  | PSintDTM-ConfMS |  |  | Rel-6 | TSG | Michael |  |  |  |
| 365 | 54.5 | BTS Conformance testing | 156d? | 2004-06-25 | 2005-01-28 |  |  | 2004-06-25 | 2004-11-12 | 101d? | 358d | finish no earlier than 2005-01-28 | G3 | 1248h |  | PSintDTM-ConfBTS |  |  | Rel-6 | TSG | Michael |  |  |  |
| 366 | 55 | CAMEL prepay interworking with SCUDIF | 206d | 2003-12-08 A | 2004-10-05 |  | 206d | 2003-12-08 | 2004-10-05 | 206d | 441.7d |  | N4 | 1648h |  | SCCAMEL |  |  | Rel-6 |  | Kimmo |  |  |  |
| 367 | 56 | **Circuit Switched Video and Voice Service Improvements** | 210d? | 2004-01-12 A | 2004-10-29 | 53% | 99.4d? | 2004-01-12 | 2004-10-29 | 210d? | 423d |  | S1 | 8488h | 4114h | CS_VSS | John Watson, Vodafone Group |  | Rel-6 | TSG | Michael | 23.801 |  |  |
| 368 | 56.1 | Stage 1 - Requirements | 199d | 2004-01-12 A | 2004-10-14 A | 100% |  | 2004-01-12 | 2004-10-14 | 199d |  | finish no earlier than 2004-10-14 | S1 | 1592h | 1592h |  | John Watson, Vodafone Group |  | Rel-6 | TSG | Michael |  |  |  |
| 369 | 56.2 | Stage 2 Study on architecture alternatives | 155d? | 2004-01-12 A | 2004-08-13 A | 100% |  | 2004-01-12 | 2004-08-13 | 155d? |  | finish no earlier than 2004-08-13 | S2 | 1240h | 1240h |  |  |  | Rel-6 |  |  |  | SP-24 |  |
| 370 | 56.3 | Stage 2 description on Redial | 130d? | 2004-05-03 A | 2004-10-29 | 85% | 19.5d? | 2004-05-03 | 2004-10-29 | 130d? | 423d | start no earlier than 2004-05-01 | S2 | 1040h | 884h |  |  |  | Rel-6 |  |  | 23.903 | SP-24 |  |
| 371 | 56.4 | GERAN2 Part | 199d | 2004-01-12 | 2004-10-14 |  |  | 2004-01-12 | 2004-10-14 | 199d | 434d | start no earlier than 2004-01-12 | G2 | 1592h |  |  |  |  | Rel-6 | TSG | Gert |  |  |  |
| 372 | 56.5 | CN3 Part | 199d? | 2004-01-12 | 2004-10-14 |  |  |  |  |  | 434d | finish no earlier than 2004-10-14 | N3 | 1592h |  |  |  |  | Rel-6 |  |  |  |  |  |
| 373 | 57 | Network Domain Security; MAP application layer security (NDS/MAPsec) | 127d? | 2004-07-06 A | 2004-12-29 | 20% | 101.6d? | 2003-07-03 | 2003-12-26 | 127d? | 380d | finish no earlier than 2003-12-26 | S3 | 1016h | 203.2h | MAPSEC | Peter Howard, Vodafone | Peter.Howard@vodafone.com | Rel-6 | TSG | Maurice |  |  |  |
| 374 | 58 | FS on Security for early IMS | 127d? | 2004-10-01 A | 2005-03-28 | 90% | 12.7d? | 2003-07-03 | 2003-12-26 | 127d? | 317d | finish no earlier than 2003-12-26 | S3 | 1016h | 914.4h | SEC-IMS | Peter Howard, Vodafone | Peter.Howard@vodafone.com | Rel-6 | TSG | Maurice |  |  |  |
| 375 | 59 | Deleted - Study of Feature Interactions Requirements | 82d? | 2002-11-08 A | 2003-03-03 | 20% | 65.6d? |  |  |  | 857d | finish no earlier than 2003-03-03 | S1 | 656h | 131.2h | FINTER |  |  | Rel-6 |  |  |  |  |  |
| 376 | 60 | Rel-7 Features listed below | 1d? | 2000-01-03 | 2000-01-03 |  |  |  |  |  | 1682d |  |  |  |  |  |  |  |  |  |  |  |  |  |
| 377 | 8.5 | **Multiple Input Multiple Output antennas (MIMO)** | 719d? | 2003-03-14 A | 2005-12-15 | 12% | 634.49d? | 2003-03-14 | 2005-03-15 | 523d? | 130d |  | R1 | 23544h | 4190.4h | MIMO | Howard Huang, Lucent | hchuang@lucent.com | Rel-7 | TSG | Cesar | TR25.876,TR25.996 |  | 2468 |
| 378 | 61.1 | MIMO - Physical layer | 392d? | 2003-09-12 A | 2005-03-15 | 60% | 156.8d? | 2003-09-12 | 2005-03-15 | 393d? | 327d | finish no earlier than 2005-03-15 | R1 | 3136h | 1881.6h | MIMO-Phys | Howard Huang, Lucent | hchuang@lucent.com | Rel-7 | TSG | MCC RAN | 25.211, 25.212, 25.213, 25.214, 25.215, 25.221, 25 |  |  |
| 379 | 61.2 | MIMO - Layer 2,3 aspects | 589d? | 2003-09-12 | 2005-12-15 |  |  | 2003-09-12 | 2004-12-15 | 329d? | 130d | finish no earlier than 2005-12-15 | R2 | 4712h |  | MIMO-L23 | Howard Huang, Lucent | hchuang@lucent.com | Rel-7 | TSG | MCC RAN | TR 25.876 |  |  |
| 380 | 61.3 | MIMO - Iub/Iur Protocol Aspects | 719d? | 2003-03-14 | 2005-12-15 |  |  | 2003-03-14 | 2004-12-15 | 459d? | 130d | finish no earlier than 2005-12-15 | R3 | 5752h |  | MIMO-IurIub | Howard Huang, Lucent | hchuang@lucent.com | Rel-7 | TSG | MCC RAN |  |  |  |
| 381 | 61.4 | MIMO - RF Radio Transmission/Reception, System Performance Requirements and Conformance Testing | 524d? | 2003-12-12 A | 2005-12-15 | 5% | 497.8d? | 2003-12-12 | 2005-03-15 | 328d? | 130d | finish no earlier than 2005-12-15 | R4 | 4192h | 209.6h | MIMO-RF | Man Hung Ng, Lucent | ngm@lucent.com | Rel-7 | TSG | MCC RAN |  |  |  |

Notes:
- 359: Started
- 361: Started
- 362: Started
- 364: Under evaluation
- 365: Under evaluation
- 373: Approved TSG#24
- 374: Approved TSG#24
- 375: SP-23 - To be abandoned?

| ID | WBS | Task | Duration | Start | Finish | Complete | Remaining | Baseline start | Baseline finish | Baseline duration | Total slack | Constraint | Resources | Work | Actual work | Text1 | Text4 | Text6 | Text7 | Text8 | Text2 | Text3 | Text9 | Text5 | Text12 |
| --- | --- | --- | --- | --- | --- | --- | --- | --- | --- | --- | --- | --- | --- | --- | --- | --- | --- | --- | --- | --- | --- | --- | --- | --- | --- |
| 382 | 62 | **PS domain and IMS impacts for supporting IMS Emergency calls** | 1340d? | 2000-08-14 A | 2005-09-30 | 39% | 821.34d? | 2000-08-14 | 2005-06-03 | 1255d? | 183d |  | S2 | 53584h | 18186.1h | EMC1 | Rainer Liebhart | Rel-7 | TSG | Sang-Ui |  |  |  |  |  |
| 383 | 10.1.1 | Service Requirements for IP-based emergency calls | 985d | 2000-09-18 A | 2004-06-25 A | 100% |  | 2000-09-18 | 2004-06-25 | 985d |  | finish no earlier than 2004-06-25 | S1 | 7880h | 7880h |  |  | Rel-7 |  |  | CCaR | 22.976 | 1314 |  |  |
| 384 | 62.2 | Stage 2 for IMS-level solution | 612d? | 2003-02-26 A | 2005-06-30 | 72% | 171.36d? | 2003-02-26 | 2004-12-15 | 471d? | 249d | finish no earlier than 2005-06-30 | S2 | 4896h | 3525.12h |  | Rainer Liebhart, Siemenws | Rel-7 | TSG |  |  | 23.228, 23.060, 23.002 |  |  |  |
| 385 | 62.3 | Stage 2 for GPRS-level solution | 252d? | 2004-10-14 A | 2005-09-30 | 10% | 226.8d? |  |  |  | 183d | finish no earlier than 2005-09-30 | S2 | 2016h | 201.6h |  |  | Rel-7 |  |  |  |  |  |  |  |
| 386 | 10.1 | **Emergency Call Enhancements for IP& PS Based Calls – stage 3** | 1255d | 2000-08-14 A | 2005-06-03 | 9% | 1143.69d | 2000-08-14 | 2005-06-03 | 1255d | 268d |  | N1 | 28272h | 2507.53h |  | Mr Atle Monrad, Ericsson | Rel-7 |  |  | CCaR |  | 1653 | Atle.Monrad@eto.ericsson.se |  |
| 387 | 10.1.2 | SIP emergency calls and packet emergency calls signalling flows | 1209d | 2000-10-17 A | 2005-06-03 | 16% | 1015.56d | 2000-10-17 | 2005-06-03 | 1209d | 268d | finish no earlier than 2005-06-03 | N1 | 9672h | 1547.52h |  | Mr Atle Monrad, Ericsson | Rel-7 |  |  | CCaR | TS 24.228 | 1315 | Atle.Monrad@eto.ericsson.se |  |
| 388 | 10.1.5 | Stage 3 for emergency calls and packet emergency calls in general | 1255d | 2000-08-14 A | 2005-06-03 | 2% | 1229.9d | 2000-08-14 | 2005-06-03 | 1255d | 268d | finish no earlier than 2005-06-03 | N1 | 10040h | 200.8h |  | Mr Atle Monrad, Ericsson | Rel-7 |  |  | CCaR | TS 24.229 | 1646 | Atle.Monrad@eto.ericsson.se |  |
| 389 | 63 | **Access Class Barring and Overload Protection** | 274d? | 2004-03-15 A | 2005-03-31 | 35% | 177.79d? | 2004-03-15 | 2004-11-30 | 187d? | 314d |  | S2 | 6000h | 2106.81h | ACBOP | Chris Pudney, Vodafone | Rel-7 | TSG | Sang-Ui |  | 23.898 |  |  |  |
| 390 | 63.1 | TR on Stage 2 | 274d? | 2004-03-15 A | 2005-03-31 | 61% | 106.86d? | 2004-03-15 | 2004-11-30 | 187d? | 314d | finish no earlier than 2005-03-31 | S2 | 2192h | 1337.12h |  |  |  | TSG |  |  |  |  |  |  |
| 391 | 63.2 | Extra ACBOP information in GERAN | 67d? | 2004-03-15 | 2004-06-15 |  |  | 2004-03-15 | 2004-06-15 | 67d? | 521d | start no earlier than 2004-03-15 | GP | 536h |  |  |  |  | TSG |  |  | 44.018 |  |  |  |
| 392 | 63.3 | Stage 3 CN aspects of ACBOP | 1d? | 2004-12-08 | 2004-12-08 |  |  |  |  |  | 395d | finish no earlier than 2004-12-08 | N1 | 8h |  |  |  |  |  |  |  |  |  |  |  |
| 393 | 63.4 | Deleted - Potential impact on Iu interface Overload functionality | 67d? | 2004-03-15 | 2004-06-15 |  |  | 2004-03-15 | 2004-06-15 | 67d? | 521d | start no earlier than 2004-03-15 | RP | 536h |  |  |  |  |  |  |  | 25.413 |  |  | RP-25 |
| 394 | 63.5 | Deleted - Extra ACBOP information in RAN | 67d? | 2004-03-15 | 2004-06-15 |  |  | 2004-03-15 | 2004-06-15 | 67d? | 521d | start no earlier than 2004-03-15 | RP | 536h |  |  |  |  |  |  |  | 25.331 |  |  | RP-25 |
| 395 | 64 | **USSD message delivery and transfer to USIM** | 1250d? | 2000-01-03 A | 2004-10-15 | 80% | 250.82d? | 2004-03-18 | 2004-10-15 | 152d? | 433d |  | S1 | 2440h | 1950.4h |  |  | Rel-7 | TSG | Michael |  | 22.090 |  |  |  |
| 396 | 64.1 | Stage 1 | 152d? | 2004-03-18 A | 2004-10-15 | 80% | 30.4d? | 2004-03-18 | 2004-10-15 | 152d? | 433d | start no earlier than 2004-03-18 | S1 | 1216h | 972.8h |  |  |  | TSG | Michael |  | 22.090 |  |  |  |
| 397 | 64.2 | WI on Alignment with requirements regarding USSD usage | 1d? | 2000-01-03 A | 2000-01-03 | 70% | 0.3d? |  |  |  | 1682d |  | T3 | 8h | 5.6h |  | Christophe Dubois (Axalto) |  | TSG |  |  |  |  |  |  |
| 398 | 65 | **Location Services enhancements Rel-7** | 513d? | 2004-06-28 A | 2006-06-15 | 16% | 432.2d? | 2000-08-28 | 2004-10-29 | 1090d? | 0d |  | S2 | 13466.4h | 2204.03h | LCS3 |  | Rel-7 |  | Sang-Ui |  | 23.271 |  |  |  |
| 399 | 65.1 | **LCS for 3GPP Interworking WLAN** | 135.3d? | 2004-06-28 A | 2005-01-03 |  | 135.3d? | 2004-06-28 | 2004-12-16 | 123d? | 377.7d |  | S1 | 2066.4h | 98.4h | LCS3-IWLAN | Mike Loushine, (Telcordia) | Rel-7 | TSG | Michael |  | 22.9xx |  |  |  |
| 400 | 65.1.1 | Feasibility study on 3GPP system to Wireless Local Area Network (WLAN) Interworking with LCS | 123d? | 2004-06-28 | 2005-01-03 |  |  | 2004-06-28 | 2004-12-16 | 123d? | 377.7d | start no earlier than 2004-06-28 | S1 | 984h |  |  |  | Rel-7 |  |  |  |  |  |  |  |
| 401 | 65.2 | **UE positioning Rel-7** | 456d? | 2004-09-15 A | 2006-06-15 | 20% | 364.8d? |  |  |  | 0d |  | RP | 7296h | 1459.2h | LCS3-UEpos |  | Rel-7 | TSG | MCC_RAN |  |  |  |  |  |
| 402 | 65.2.1 | Inclusion of Uplink TDOA UE positioning method in the UTRAN specifications | 456d? | 2004-09-15 A | 2006-06-15 | 20% | 364.8d? |  |  |  | 0d | finish no earlier than 2006-06-15 | R2 | 3648h | 729.6h | LCS3-UEPos-UTDOA | Robert Gross, TruePosition | Rel-7 | TSG | MCC_RAN |  | TS25.305, TS25.453 |  | rlgross@trueposition.com |  |
| 403 | 66 | **Toward A-GNSS concept** | 206.8d? | 2004-06-28 A | 2005-04-12 | 10% | 186.12d? | 2004-06-28 | 2005-03-16 | 188d? | 306.2d |  | S1 | 3158.4h | 300.8h | LCS3-AGNSS | Michel MONNERAT | Rel-7 | TSG | Michael |  |  |  | Michel.monnerat@space.alcatel.fr |  |
| 404 | 66.1 | Toward A-GNSS concept | 188d? | 2004-06-28 A | 2005-04-12 | 10% | 169.2d? | 2004-06-28 | 2005-03-16 | 188d? | 306.2d | start no earlier than 2004-06-28 | GP | 1504h | 150.4h | AGNSS-GP | Richard Couty, ALCATEL SA | Rel-7 | TSG | Paolo |  |  |  | richard.couty@space.alcatel.fr |  |
| 405 | 67 | **FS on applicability of GALILEO for LCS** | 779d? | 2002-07-08 A | 2005-06-30 | 39% | 475.24d? | 2002-07-08 | 2004-06-30 | 518d? | 249d |  | S2 | 13424h | 3804.4h |  |  | Rel-7 |  |  |  |  |  |  |  |
| 406 | 67.1 | TR on Stage 2 | 779d? | 2002-07-08 A | 2005-06-30 | 45% | 428.45d? | 2002-07-08 | 2004-06-30 | 518d? | 249d | finish no earlier than 2005-06-30 | S2 | 6232h | 2804.4h |  |  | Rel-7 |  |  |  |  |  |  |  |
| 407 | 67.2 | deleted - GERAN review of the TR | 120d? | 2003-08-25 | 2004-02-06 |  |  | 2003-08-25 | 2004-02-06 | 120d? | 613d | finish no earlier than 2004-02-06 | GP | 960h |  |  |  | Rel-7 |  |  |  |  |  |  |  |

Notes:
- 392: NEW - inserted on 2/9/2004
- 400: DAB - Should be SA1
- 402: Approved at RP#25 as RP-040387

| ID | WBS | Task | Type | Duration | Start | Finish | Complete | Remaining | Baseline start | Baseline finish | Baseline duration | Total slack | Constraint | Resources | Work | Actual work | Text1 | Text4 | Text5 | Text6 | Text7 | Text8 |
| --- | --- | --- | --- | --- | --- | --- | --- | --- | --- | --- | --- | --- | --- | --- | --- | --- | --- | --- | --- | --- | --- | --- |
| 408 | 68 | **Enhancements of VGCS in public networks for communication of public authority officials** |  | 179d? | 2004-06-28 A | 2005-03-03 | 44% | 100.03d? | 2004-06-28 | 2004-12-16 | 123d? | 334d |  | S1 | 3640h | 1605.95h | EGCS | Joerg Swetina (Siemens AG) | joerg.swetina@SIEMENS.COM | Rel-7 | TSG | Michael |
| 409 | 68.1 | Stage 1 |  | 123d? | 2004-06-28 A | 2004-12-16 | 99% | 1.23d? | 2004-06-28 | 2004-12-16 | 123d? | 390d | finish no earlier than 2004-12-16 | S1 | 984h | 974.16h | EGCS | Joerg Swetina (Siemens AG) | joerg.swetina@SIEMENS.COM | Rel-7 | TSG | Michael |
| 410 | 68.2 | Enhancements of VGCS in public networks for communication of public authority officials |  | 153d? | 2004-08-03 | 2005-03-03 |  |  |  |  |  | 334d | finish no earlier than 2005-03-03 | N1 | 1224h |  | EGCS | Siemens |  | Rel-7 | TSG | Andrijana |
| 411 | 69 | Behaviour of Multi system UEs |  | 188d? | 2004-06-28 A | 2005-03-16 | 35% | 122.2d? | 2004-06-28 | 2005-03-16 | 188d? | 325d | start no earlier than 2004-06-28 | S1 | 1504h | 526.4h | BMSU | D Williams (QUALCOMM) | dwilliams@qualcomm.com | Rel-7 | TSG | Michael |
| 412 | 70 | Selective Disabling of UE Capabilities |  | 188d? | 2004-06-28 A | 2005-03-16 | 20% | 150.4d? | 2004-06-28 | 2005-03-16 | 188d? | 325d | start no earlier than 2004-06-28 | S1 | 1504h | 300.8h | SDoUE | Nigel Barnes (Motorola Ltd) | Nigel.Barnes@motorola.com | Rel-7 | TSG | Michael |
| 413 | 71 | **FS on IMS with real time services deployment** |  | 384d? | 2004-06-28 A | 2005-12-15 | 80% | 76.46d? | 2004-06-28 | 2005-12-15 | 384d? | 129d |  | S1 | 7640h | 4362.65h | IRTSD |  |  | Rel-7 | TSG | Michael |
| 414 | 71.1 | Combining CS calls and IMS sessions |  | 384d? | 2004-06-28 A | 2005-12-15 | 85% | 57.6d? | 2004-06-28 | 2005-12-15 | 384d? | 129d | start no earlier than 2004-06-28 | S1 | 3072h | 2611.2h | IRTSD-CS_IMS |  |  | Rel-7 | TSG | Michael |
| 415 | 71.2 | IMS services using CS bearers |  | 187d? | 2004-06-28 A | 2005-03-15 | 70% | 56.1d? | 2004-06-28 | 2005-12-15 | 384d? | 326d | finish no earlier than 2005-03-15 | S2 | 1496h | 1047.2h | IRTSD-IMSCS | Mark Watson (Nortel Networks) |  | Rel-7 | TSG | Sang-Ui |
| 416 | 72 | All-IP Network Feasibility Study |  | 188d? | 2004-06-28 A | 2005-03-16 | 75% | 47d? | 2004-06-28 | 2005-03-16 | 188d? | 325d | start no earlier than 2004-06-28 | S1 | 1504h | 1128h | AIPFS | Chris Sachno (NTT DoCoMo) | c.masyu@nttdocomo.co.jp | Rel-7 | TSG | Michael |
| 417 | 73 | Enhancement of E2E QoS |  | 213.4d? | 2004-06-28 A | 2005-06-13 | 30% | 149.38d? | 2004-06-28 | 2005-03-16 | 188d? | 262d | finish no earlier than 2005-06-13 | S2 | 1707.2h | 512.16h | QoS7 |  |  | Rel-7 | TSG | Sang-Ui |
| 418 | 74 | **System enhancements for fixed broadband access to IMS** |  | 258d? | 2004-08-03 A | 2005-07-28 | 5% | 246.16d? | 2003-06-06 | 2004-08-31 | 323d? | 229d |  | S2 | 3385.6h | 155.42h | FBI |  |  | Rel-7 | TSG | Sang-Ui |
| 419 | 74.1 | Stage 2 |  | 206d? | 2004-10-14 A | 2005-07-28 | 8% | 189.52d? | 2003-06-06 | 2004-08-31 | 323d? | 229d | finish no earlier than 2005-07-28 | S2 | 1648h | 131.84h | FBI |  |  | Rel-7 | TSG | Sang-Ui |
| 420 | 74.2 | Protocol impact from providing IMS services via fixed broadband |  | 153d? | 2004-08-03 | 2005-03-03 |  |  |  |  |  | 334d | finish no earlier than 2005-03-03 | N1 | 1224h |  | FBI | Siemens |  | Rel-7 | TSG | Andrijana |
| 421 | 75 | Deleted - IMS Phase 3 |  | 833d? | 2001-01-01 A | 2005-06-08 | 29% | 591.28d? |  |  |  | 265d |  | S2 | 6664h | 1933.75h |  |  |  | Rel-7 |  |  |
| 422 | 16.7 | **IMS Local services (CN WID needed)** |  | 1158d? | 2001-01-01 A | 2005-06-08 | 29% | 821.97d? | 2001-01-01 | 2004-06-04 | 895d? | 265d |  | S2 | 18224h | 5192.02h |  |  |  | Rel-7 |  |  |
| 423 | 16.7.1 | Stage 2 (SA2 propose delete this) |  | 325d | 2001-01-01 A | 2002-03-29 A | 100% |  | 2001-01-01 | 2002-03-29 | 325d |  | start no earlier than 2001-01-01 | S2 | 2600h | 2600h |  |  |  | Rel-7 |  |  |
| 424 | 76.2 | Stage 3 for IMS Local services |  | 151d? | 2004-11-10 | 2005-06-08 |  |  | 2002-12-13 | 2004-06-04 | 386d? | 265d | finish no earlier than 2005-06-08 | N1 | 1208h |  |  | Keith Drage, Lucent | drage@lucent.com | Rel-7 |  |  |
| 425 | 76.3 | Mp (MRFC - MRFP) interface - CN4 Part (check supporting companies) |  | 644d | 2002-12-13 | 2005-06-01 |  |  | 2002-12-13 | 2004-11-30 | 513d | 270d | finish no earlier than 2005-06-01 | N4 | 5152h |  | IMS-CCR-Mp |  |  | Rel-7 |  |  |
| 426 | 77 | IMS Stage 3 IETF Protocol alignment |  | 261d? | 2004-12-10 | 2005-12-09 |  |  |  |  |  | 133d | finish no earlier than 2005-12-09 | N1 | 2088h |  |  |  |  | Rel-7 |  |  |
| 427 | 78 | Deleted - Improvements of Radio Interface | milestone | 0d? | 2004-09-15 | 2004-09-15 |  |  | 2000-08-14 | 2004-09-15 | 1068d | 456d | start no earlier than 2004-09-15 | RP |  |  | RInImp |  |  | Rel-7 | TSG | Cesar |
| 428 | 79 | **Rel-7 Improvements of the Radio Interface** |  | 326d? | 2004-09-15 A | 2005-12-15 | 3% | 314.71d? |  |  |  | 130d |  | RP | 9400h | 325.52h | RInImp |  |  | Rel-7 |  |  |
| 429 | 79.1 | UMTS 2.6 GHz |  | 196d? | 2004-09-15 A | 2005-06-15 | 15% | 166.6d? |  |  |  | 260d | finish no earlier than 2005-06-15 | R4 | 1568h | 235.2h | RInImp-UMTS2600 | Jussi Numminen, Nokia | jussi.numminen@nokia.com | Rel-7 | TSG | MCC_RAN |
| 430 | 79.2 | UMTS 2.6 GHz TDD |  | 261d? | 2004-12-15 | 2005-12-15 |  |  |  |  |  | 130d | finish no earlier than 2005-12-15 | R4 | 2088h |  | RInImp-UMTS2600TDD | Shin Horng Wong (IPWireless) |  | Rel-7 | TSG | MCC_RAN |
| 431 | 79.3 | UMTS 900 MHz |  | 196d? | 2004-12-15 | 2005-09-15 |  |  |  |  |  | 195d | finish no earlier than 2005-09-15 | R4 | 1568h |  | RInImp-UMTS900 | Yannick Li (Nortel) |  | Rel-7 | TSG | MCC_RAN |
| 432 | 79.4 | UE Antenna Performance Evaluation Method and Requirements |  | 196d? | 2004-12-15 | 2005-09-15 |  |  |  |  |  | 195d | finish no earlier than 2005-09-15 | R4 | 1568h |  | RInImp-UEAnt | Christian Bergljung (TeliaSonera) | Christian.Bergljung@TeliaSonera.com | Rel-7 | TSG | MCC_RAN |

Notes:
- 408: Text3: 42.068, 43.068
- 409: Text3: 42.068, 43.068
- 410: WI sent to NP#25 for approval / Text3: 43.068, 44.068, 24.008, 29.002
- 411: Text3: 22.936
- 412: Text3: 22.xxx
- 414: Text3: 22.979, 23.899
- 415: Text3: 23.899
- 416: Text3: 22.978
- 417: DAB - pushed back to June / Text3: 23.802
- 420: WI sent to NP#25 for approval / Text3: new TR, 24.229, 29.229, 29.163, 29.209
- 422: Text3: 23.228
- 423: DAB - Not yet required in SA2 as it exists in previous releases
- 425: 27/11/2002 KK: WID approved at CN#18 (NP-020601)........
- 427: This is a generic feature without particular end date
- 429: Approved at RP#25 as RP-040377 / Text3: TS25.101, TS25.104, TS25.133, TS25.141, TS25.331, TS25.942, TS25.306, TS25.307, TS34.121
- 430: Text3: 25.102, 25.105, 25.113, 25.123, 25.142, 25.331, 25.942, 25.306, 25.307, 34.122, 34.124
- 431: Text3: 25.101, 25.104, 25.113, 25.133, 25.141, 25.331, 25.942, 25.306, 25.307, 34.121
- 432: Text3: TS25.101

| ID | WBS | Task | Duration | Start | Finish | Complete | Remaining | Total slack | Constraint | Resources | Work | Actual work | Text1 | Text4 | Text5 | Text6 | Text7 | Text8 |
| --- | --- | --- | --- | --- | --- | --- | --- | --- | --- | --- | --- | --- | --- | --- | --- | --- | --- | --- |
| 433 | 80 | **7.68Mcps TDD option** | 390d? | 2004-09-15 A | 2006-03-15 | 1% | 384.7d? | 66d |  | RP | 14592h | 198.43h | VHCRTDD | Martin Beale, IPWireless | mbeale@ipwireless.com | Rel-7 | TSG | MCC_RAN |
| 434 | 80.1 | 7.68Mcps TDD option: Stage 2 | 261d? | 2004-09-15 | 2005-09-15 |  |  | 195d | finish no earlier than 2005-09-15 | R1 | 2088h |  | VHCRTDD-Stage2 | Martin Beale, IPWireless | mbeale@ipwireless.com | Rel-7 | TSG | MCC_RAN |
| 435 | 80.2 | 7.68Mcps TDD option: Physical Layer | 261d? | 2004-09-15 | 2005-09-15 |  |  | 195d | finish no earlier than 2005-09-15 | R1 | 2088h |  | VHCRTDD-Phys | Martin Beale, IPWireless | mbeale@ipwireless.com | Rel-7 | TSG | MCC_RAN |
| 436 | 80.3 | 7.68Mcps TDD option: Layer 2 and layer 3 protocol aspects | 261d? | 2004-09-15 | 2005-09-15 |  |  | 195d | finish no earlier than 2005-09-15 | R2 | 2088h |  | VHCRTDD-L23 | Derek Richards, IPWireless | drichards@ipwireless.com | Rel-7 | TSG | MCC_RAN |
| 437 | 80.4 | 7.68Mcps TDD option: UTRAN Iub/Iur Protocol Aspects | 261d? | 2004-09-15 | 2005-09-15 |  |  | 195d | finish no earlier than 2005-09-15 | R3 | 2088h |  | VHCRTDD-IurIub | Peter Legg, IPWireless | plegg@ipwireless.com | Rel-7 | TSG | MCC_RAN |
| 438 | 80.5 | 7.68Mcps TDD option: RF Radio Transmission/ Reception, System Performance Requirements and Conformance Testing | 390d? | 2004-09-15 A | 2006-03-15 | 5% | 370.5d? | 66d | finish no earlier than 2006-03-15 | R4 | 3120h | 156h | VHCRTDD-RF | Shin Horng Wong, IPWireless | shwong@ipwireless.com | Rel-7 | TSG | MCC_RAN |
| 439 | 81 | FS on Evolved UTRA and UTRAN | 130d? | 2004-12-15 | 2005-06-15 |  |  | 261d | finish no earlier than 2005-06-15 | RP | 1040h |  | RANFS-Evo | Takehiro Nakamura (NTT DoCoMo) | nakamurata@NTTDOCOMO.CO.JP | Rel-7 | TSG | MCC_RAN |
| 440 | 82 | **Rel-7 RAN improvements** | 196d? | 2004-12-15 A | 2005-09-14 | 30% | 137.2d? | 195d |  | RP | 3136h | 940.8h | RANimp |  |  | Rel-7 | TSG | MCC_RAN |
| 441 | 82.1 | Optimisation of channelisation code utilisation for 1.28 Mcps TDD | 196d? | 2004-12-15 A | 2005-09-14 | 30% | 137.2d? | 195d | finish no earlier than 2005-09-14 | R1 | 1568h | 470.4h | RANimp-RABSE-CodOptLCRTDD | Nicholas Anderson (IPWireless) |  | Rel-7 | TSG |  |
| 442 | 83 | Support of SMS and MMS over generic 3GPP IP access | 173d? | 2004-10-14 A | 2005-06-13 | 15% | 147.05d? | 262d | finish no earlier than 2005-06-13 | S2 | 1384h | 207.6h | SMSIP |  |  | Rel-7 | TSG |  |
| 443 | 84 | Evolution of Policy Control and Charging | 315d? | 2004-10-14 A | 2005-12-28 | 8% | 289.8d? | 120d | finish no earlier than 2005-12-28 | S2 | 2520h | 201.6h | PCC |  |  | Rel-7 | TSG |  |
| 444 | 85 | Support for GNSS in GERAN (Global Navigation Satellite System) | 161d? | 2004-08-27 | 2005-04-08 |  |  | 308d | start no earlier than 2004-08-27 | GP | 1288h |  | GNSS | Richard Couty, ALCATEL SA | richard.couty@space.alcatel.fr | Rel-7 | TSG | Paolo |
| 445 | 86 | FS of enhanced support of Video Telephony | 161d? | 2004-08-27 A | 2005-04-08 | 10% | 144.9d? | 308d | finish no earlier than 2005-04-08 | GP | 1288h | 128.8h | VIDGER | Stefan Eriksson, Ericsson | stefan.g.eriksson@ericsson.com | Rel-7 | TSG | Paolo |
| 446 | 87 | **Generic Access to A/Gb Interface (GAAI)** | 261d? | 2004-06-25 A | 2005-06-24 | 29% | 186.48d? | 253d |  | GP | 6760h | 1930.19h | GAAI | Motorola |  | Rel-7 | TSG | Paolo |
| 447 | 87.1 | FS on GAAI | 46d? | 2004-06-25 A | 2004-08-27 A | 100% |  |  | finish no earlier than 2004-08-27 | GP | 368h | 368h | GAAG | Motorola |  | Rel-7 | TSG | Paolo |
| 448 | 87.2 | GAAI – Stage 2 | 161d? | 2004-08-27 A | 2005-04-08 | 75% | 40.25d? | 308d | finish no earlier than 2005-04-08 | GP | 1288h | 966h | GAAI-Stage2 |  |  | Rel-7 | TSG |  |
| 449 | 87.3 | GAAI – Stage 3 | 161d? | 2004-08-27 | 2005-04-08 |  |  | 308d | finish no earlier than 2005-04-08 | GP | 1288h |  | GAAI-Stage3 |  |  | Rel-7 | TSG |  |
| 450 | 87.4 | MS Conformance Test for GAAI | 216d? | 2004-08-27 | 2005-06-24 |  |  | 253d | finish no earlier than 2005-06-24 | GP | 1728h |  | GAAI-CT |  |  | Rel-7 | TSG |  |
| 451 | 88 | Enhancements of VGCS in public networks for communication of public authority officials | 80.5d? | 2004-12-17 | 2005-04-08 |  |  | 308d | finish no earlier than 2005-04-08 | GP;; G2 | 1288h |  | EVGCS | Ken Isaacs (Siemens) | kenneth.isaacs@roke.co.uk | Rel-7 | TSG | Paolo |

Notes:
- 433: Approved at RP#25 as RP-040365
- 434: Approved at RP#25 as RP-040365 / Text3: New specification
- 435: Approved at RP#25 as RP-040365 / Text3: TS25.221, TS25.222, TS25.223, TS25.224,TS25.225
- 436: Approved at RP#25 as RP-040365 / Text3: TS25.301, TS25.302, TS25.305, TS25.306, TS25.321, TS25.331
- 437: Approved at RP#25 as RP-040365 / Text3: TS25.401, TS25.420, TS25.423, TS25.425, TS25.427, TS25.430, TS25.433, TS25.435
- 438: Approved at RP#25 as RP-040365 / Text3: TS25.102, TS25.105, TS25.123, TS25.133, TS25.142
- 439: vice rapporteur Don Zelmar (Cingular)
- 440: Generic feature
- 442: DAB - pushed back to June
- 444: To become a BB under 31051 !
- 445: Feasibility Study
- 447: Feasibility Study / Text3: TR 43.901
- 449: Not started
- 450: Not started
